# DISEÑO Y CONSTRUCCIÓN EDIFICIO VIS

Schedule from MS Project, 2024-01-01 to 2025-12-31, status date 2024-03-30, costs in $, A marks actual dates.

## Calendars

- Terre PI: Mon-Fri 07:00-12:00, 13:00-17:00; Sat 07:00-12:00; Sun off. Exceptions (off unless hours are given): 2024-01-01 (1 enero), 2024-01-08 (8 enero), 2024-03-25 (25 marzo), 2024-03-28 (28 de marzo), 2024-03-29 (29 de marzo), 2024-05-01 (1 de mayo), 2024-05-13 (13 de mayo), 2024-06-03 (3 de junio), 2024-06-10 (10 de junio), 2024-07-01 (01 julio), 2024-07-20 (20 julio), 2024-08-07 (7 agosto), 2024-10-14 (14 octubre), 2024-11-04 (4 noviembre), 2024-11-11 (11 noviembre), 2024-12-08 (8 diciembre), 2024-12-25 (25 diciembre), 2025-01-01 (01 enero), 2025-01-06 (06 enero), 2025-03-24 (24 marzo), 2025-04-17 (17 abril), 2025-04-18 (18 abril), 2025-05-01 (01 mayo), 2025-06-02 (02 junio), 2025-06-23 (23 de junio), 2025-06-30 (30 de junio), 2025-07-20 (20 de julio), 2025-08-07 (7 de agosto), 2025-08-18 (18 de agosto), 2025-10-13 (13 de octubre), 2025-11-03 (3 de noviembre), 2025-11-17 (17 de noviembre), 2025-12-08 (8 de diciembre), 2025-12-25 (25 de diciembre).

## Schedule

| ID | WBS | Task | Type | Duration | Start | Finish | Predecessors | Complete | Remaining | Total slack | Free slack | Cost | Actual cost |
| --- | --- | --- | --- | --- | --- | --- | --- | --- | --- | --- | --- | --- | --- |
| 1 | 1 | INICIO DE PROYECTO | milestone | 0d | 2024-01-01 A | 2024-01-01 A |  | 100% |  |  |  |  |  |
| 2 | 2 | **ESTUDIOS PREVIOS** |  | 29.5d | 2024-01-02 A | 2024-02-05 |  | 93% | 1.97d | 588.12d |  | 6,000,000 | 5,760,000 |
| 3 | 2.1 | **Análisis preeliminares** |  | 29.5d | 2024-01-02 A | 2024-02-05 |  | 93% | 1.97d | 588.12d |  | 6,000,000 | 5,760,000 |
| 4 | 2.1.1 | Análisis jurídico |  | 10d | 2024-01-02 A | 2024-01-12 A | 1 | 100% |  |  |  | 1,200,000 | 1,200,000 |
| 5 | 2.1.2 | Análisis socio-ambiental |  | 10d | 2024-01-02 A | 2024-01-12 A | 4SS | 100% |  |  |  | 1,200,000 | 1,200,000 |
| 6 | 2.1.3 | Estudio técnico preeliminar |  | 20d | 2024-01-06 A | 2024-01-29 | 5SS+5d | 80% | 4d | 593.75d |  | 1,200,000 | 960,000 |
| 7 | 2.1.4 | Evaluación financiera |  | 10d | 2024-01-18 A | 2024-01-29 A | 6SS+10d | 100% |  |  |  | 1,200,000 | 1,200,000 |
| 8 | 2.1.5 | Estudio de mercado |  | 10d | 2024-01-24 A | 2024-02-05 A | 7SS+5d | 100% |  |  |  | 1,200,000 | 1,200,000 |
| 9 | 3 | **ESTUDIOS Y DISEÑOS** |  | 79.12d | 2024-02-05 A | 2024-05-08 |  | 61% | 31.18d | 509d |  | 106,000,000 | 65,200,000 |
| 10 | 3.1 | **Estudios básicos** |  | 21.12d | 2024-02-05 A | 2024-02-28 A |  | 100% |  |  |  | 18,000,000 | 18,000,000 |
| 11 | 3.1.1 | Levantamiento Topográfico |  | 10d | 2024-02-05 A | 2024-02-15 A | 8 | 100% |  |  |  | 7,500,000 | 7,500,000 |
| 12 | 3.1.2 | Estudió Geotécnico |  | 10d | 2024-02-16 A | 2024-02-28 A | 11 | 100% |  |  |  | 10,500,000 | 10,500,000 |
| 13 | 3.2 | **Diseños bajo metodología BIM** |  | 45d | 2024-02-28 A | 2024-04-23 |  | 57% | 19.57d | 522d |  | 67,500,000 | 37,500,000 |
| 14 | 3.2.1 | Diseño Arquitectónico metodología BIM |  | 40d | 2024-02-28 A | 2024-04-12 A | 12 | 100% |  |  |  | 22,500,000 | 22,500,000 |
| 15 | 3.2.2 | Diseño Estructural metodología BIM |  | 25d | 2024-03-15 A | 2024-04-12 | 14SS+15d | 50% | 12.5d | 530.12d | 0d | 15,000,000 | 7,500,000 |
| 16 | 3.2.3 | Diseño Hidrosanitario y de gas y RCI metodología BIM |  | 25d | 2024-03-21 A | 2024-04-18 | 15SS+5d | 50% | 12.5d | 525.38d | 0d | 15,000,000 | 7,500,000 |
| 17 | 3.2.4 | Diseño Eléctrico y de Voz y datos metodología BIM |  | 25d | 2024-03-21 | 2024-04-23 | 16SS |  |  | 0d |  | 15,000,000 |  |
| 18 | 3.3 | **Estudios especiales** |  | 38d | 2024-03-21 A | 2024-05-08 |  | 51% | 18.46d | 509d |  | 20,500,000 | 9,700,000 |
| 19 | 3.3.1 | Estudio Bioclimático |  | 20d | 2024-03-21 A | 2024-04-12 | 17SS | 80% | 4d | 530.38d |  | 10,500,000 | 8,400,000 |
| 20 | 3.3.2 | Presupuesto y programación |  | 15d | 2024-04-19 A | 2024-05-08 | 17 | 13% | 13d | 0d |  | 10,000,000 | 1,300,000 |
| 21 | 4 | **LICENCIAS Y PERMISOS** |  | 130d | 2024-05-08 | 2024-10-08 |  |  |  | 0d |  | 3,118,000 |  |
| 22 | 4.1 | **Trámite ante curaduría** |  | 130d | 2024-05-08 | 2024-10-08 |  |  |  | 0d |  | 300,000 |  |
| 23 | 4.1.1 | Licencia de Construcción |  | 130d | 2024-05-08 | 2024-10-08 | 20 |  |  | 0d |  | 300,000 |  |
| 24 | 4.2 | **Trámites ante entidades distritales** |  | 30d | 2024-09-04 | 2024-10-08 |  |  |  | 379d |  | 1,318,000 |  |
| 25 | 4.2.1 | PIN ambiental |  | 30d | 2024-09-04 | 2024-10-08 | 23FF |  |  | 379d |  | 698,000 |  |
| 26 | 4.2.2 | Plan de manejo de tránsito |  | 30d | 2024-09-04 | 2024-10-08 | 23FF |  |  | 379d |  | 620,000 |  |

| ID | WBS | Task | Duration | Start | Finish | Predecessors | Total slack | Free slack | Cost |
| --- | --- | --- | --- | --- | --- | --- | --- | --- | --- |
| 27 | 4.3 | **Trámites ante empresas prestadoras de servicios públicos** | 20d | 2024-09-16 | 2024-10-08 |  | 0d |  | 1,500,000 |
| 28 | 4.3.1 | Disponibilidad de servicio eléctrico | 20d | 2024-09-16 | 2024-10-08 | 23FF | 379d |  | 500,000 |
| 29 | 4.3.2 | Disponibilidad de servicio de gas | 20d | 2024-09-16 | 2024-10-08 | 23FF | 379d |  | 500,000 |
| 30 | 4.3.3 | Disponibilidad de servicio de acueducto | 20d | 2024-09-16 | 2024-10-08 | 23FF | 0d |  | 500,000 |
| 31 | 5 | **ACTIVIDADES PREVIAS AL INICIO DE OBRA** | 15d | 2024-10-08 | 2024-10-25 |  | 0d |  | 17,525,088 |
| 32 | 5.1 | **Actividades preeliminares de obra** | 14d | 2024-10-08 | 2024-10-24 |  | 0d |  | 15,525,088 |
| 33 | 5.1.1 | Cerramiento de obra | 6d | 2024-10-08 | 2024-10-16 | 30 | 0d |  | 8,718,574 |
| 34 | 5.1.2 | Campamento | 3d | 2024-10-16 | 2024-10-18 | 33 | 365d | 0d | 4,006,514 |
| 35 | 5.1.3 | Topografia preeliminar | 8d | 2024-10-16 | 2024-10-24 | 33 | 365d |  | 2,000,000 |
| 36 | 5.1.4 | Levantamiento de actas de vecindad | 5d | 2024-10-18 | 2024-10-24 | 34 | 365d |  | 800,000 |
| 37 | 5.2 | **Provisionales de obra** | 15d | 2024-10-08 | 2024-10-25 |  | 0d |  | 2,000,000 |
| 38 | 5.2.1 | TPO acueducto | 15d | 2024-10-08 | 2024-10-25 | 33SS | 0d |  | 1,000,000 |
| 39 | 5.2.2 | Provisional eléctrica | 15d | 2024-10-08 | 2024-10-25 | 38SS | 0d |  | 1,000,000 |
| 40 | 6 | **CONSTRUCCIÓN** | 338d | 2024-10-25 | 2025-11-29 |  | 0d |  | 2,492,427,484.59 |
| 41 | 6.1 | **Obra negra** | 212d | 2024-10-25 | 2025-07-05 |  | 0d |  | 982,914,221.22 |
| 42 | 6.1.1 | **Cimentación** | 78d | 2024-10-25 | 2025-01-28 |  | 0d |  | 352,305,470.52 |
| 43 | 6.1.1.1 | **Actividades previas cimentación** | 4d | 2024-10-25 | 2024-10-30 |  | 0d |  | 7,160,000 |
| 44 | 6.1.1.1.1 | Excavación mecánica | 3d | 2024-10-25 | 2024-10-29 | 39 | 0d |  | 2,600,000 |
| 45 | 6.1.1.1.2 | Localización y replanteo ejes y niveles | 1d | 2024-10-29 | 2024-10-30 | 44 | 0d |  | 4,560,000 |
| 46 | 6.1.1.2 | **Pilotes** | 21d | 2024-10-30 | 2024-11-26 |  | 0d |  | 123,758,359.88 |
| 47 | 6.1.1.2.1 | Perforación mecánica pilotes | 15d | 2024-10-30 | 2024-11-19 | 45 | 0d |  | 12,209,400 |
| 48 | 6.1.1.2.2 | Armado de canastas pilotes | 15d | 2024-11-02 | 2024-11-21 | 47SS+3d | 0d |  | 51,075,409.88 |
| 49 | 6.1.1.2.3 | Fundida de pilotes concreto 28mpa | 15d | 2024-11-07 | 2024-11-26 | 48SS+3d | 0d |  | 60,473,550 |
| 50 | 6.1.1.3 | **Cabezales y vigas de cimentación** | 24d | 2024-11-26 | 2024-12-23 |  | 0d |  | 72,320,809.88 |
| 51 | 6.1.1.3.1 | Concreto ciclópeo | 2d | 2024-11-26 | 2024-11-27 | 49 | 0d |  | 4,500,000 |
| 52 | 6.1.1.3.2 | Solado de limpieza | 1d | 2024-11-27 | 2024-11-28 | 51 | 0d |  | 300,000 |
| 53 | 6.1.1.3.3 | Armado de refuerzo cabezales y vigas de cimentación | 15d | 2024-11-28 | 2024-12-16 | 52 | 0d |  | 51,075,409.88 |
| 54 | 6.1.1.3.4 | Armado formaleta cabezales y vigas de cimentación | 15d | 2024-12-02 | 2024-12-19 | 53SS+3d | 0d |  | 6,000,000 |
| 55 | 6.1.1.3.5 | Fundida de cabezales y vigas concreto 28mpa | 15d | 2024-12-05 | 2024-12-23 | 54SS+3d | 0d |  | 10,445,400 |

| ID | WBS | Task | Duration | Start | Finish | Predecessors | Total slack | Free slack | Cost |
| --- | --- | --- | --- | --- | --- | --- | --- | --- | --- |
| 56 | 6.1.1.4 | **Tanque** | 6d | 2024-12-23 | 2024-12-30 |  | 0d |  | 61,080,129.88 |
| 57 | 6.1.1.4.1 | Solado de limpieza | 1d | 2024-12-23 | 2024-12-24 | 55 | 0d |  | 300,000 |
| 58 | 6.1.1.4.2 | Armado de refuerzo tanque | 3d | 2024-12-24 | 2024-12-27 | 57 | 0d |  | 51,075,409.88 |
| 59 | 6.1.1.4.3 | Armado formaleta tanque | 3d | 2024-12-26 | 2024-12-30 | 58SS+1d | 0d |  | 800,000 |
| 60 | 6.1.1.4.4 | Fundida de tanque concreto 28mpa | 3d | 2024-12-26 | 2024-12-30 | 59SS+1d | 0d |  | 8,904,720 |
| 61 | 6.1.1.5 | **Muros de contención** | 17d | 2024-12-31 | 2025-01-21 |  | 0d |  | 60,375,409.88 |
| 62 | 6.1.1.5.1 | Solado de limpieza | 3d | 2024-12-31 | 2025-01-03 | 60 | 0d |  | 300,000 |
| 63 | 6.1.1.5.2 | Armado de refuerzo muros de contención | 10d | 2025-01-03 | 2025-01-16 | 62 | 0d |  | 51,075,409.88 |
| 64 | 6.1.1.5.3 | Armado formaleta muros de contención | 10d | 2025-01-07 | 2025-01-18 | 63SS+2d | 0d |  | 2,000,000 |
| 65 | 6.1.1.5.4 | Fundida de muros de contención concreto 28mpa | 10d | 2025-01-09 | 2025-01-21 | 64SS+2d | 0d |  | 7,000,000 |
| 66 | 6.1.1.6 | **Placa de cimentación** | 6d | 2025-01-21 | 2025-01-28 |  | 0d |  | 27,610,761 |
| 67 | 6.1.1.6.1 | Solado de limpieza | 1d | 2025-01-21 | 2025-01-22 | 65 | 0d |  | 3,000,000 |
| 68 | 6.1.1.6.2 | Armado de refuerzo placa de cimentación | 4d | 2025-01-22 | 2025-01-27 | 67 | 286d | 0d | 7,425,883 |
| 69 | 6.1.1.6.3 | Fundida de placa de cimentación concreto 28mpa | 4d | 2025-01-23 | 2025-01-28 | 68SS+1d | 286d | 0d | 17,184,878 |
| 70 | 6.1.2 | **Estructura en concreto** | 140d | 2025-01-21 | 2025-07-05 |  | 0d |  | 630,608,750.7 |
| 71 | 6.1.2.1 | **Estructura Piso 1** | 12d | 2025-01-21 | 2025-02-03 |  | 0d |  | 62,721,263.37 |
| 72 | 6.1.2.1.1 | **Placa Piso 1** | 9d | 2025-01-21 | 2025-01-30 |  | 0d |  | 31,767,174 |
| 73 | 6.1.2.1.1.1 | Muro en mamposteria confinada | 4d | 2025-01-21 | 2025-01-24 | 67SS | 0d |  | 7,500,000 |
| 74 | 6.1.2.1.1.2 | Columnetas | 4d | 2025-01-21 | 2025-01-24 | 73SS | 0d |  | 3,500,000 |
| 75 | 6.1.2.1.1.3 | Relleno liviano | 2d | 2025-01-25 | 2025-01-28 | 74 | 0d |  | 2,600,000 |
| 76 | 6.1.2.1.1.4 | Malla electrosoldada Piso 1 | 1d | 2025-01-28 | 2025-01-29 | 75 | 0d |  | 3,901,173 |
| 77 | 6.1.2.1.1.5 | Fundida de placa de Piso 1 concreto 28mpa | 2d | 2025-01-29 | 2025-01-30 | 76SS+1d | 0d |  | 14,266,001 |
| 78 | 6.1.2.1.2 | **Columnas Piso 1** | 3d | 2025-01-30 | 2025-02-03 |  | 0d |  | 30,954,089.37 |
| 79 | 6.1.2.1.2.1 | Armada de acero de refuerzo columnas Piso 1 | 1d | 2025-01-30 | 2025-01-31 | 77 | 0d |  | 21,706,076 |
| 80 | 6.1.2.1.2.2 | Armada de formaleta columnas Piso 1 | 1d | 2025-01-31 | 2025-02-03 | 79 | 0d |  | 3,600,000 |
| 81 | 6.1.2.1.2.3 | Fundida de columnas Piso 1 concreto 35mpa | 1d | 2025-02-03 | 2025-02-03 | 80 | 0d |  | 5,648,013.37 |

| ID | WBS | Task | Duration | Start | Finish | Predecessors | Total slack | Cost |
| --- | --- | --- | --- | --- | --- | --- | --- | --- |
| 82 | 6.1.2.2 | **Estructura Piso 2** | 11d | 2025-02-04 | 2025-02-15 |  | 0d | 47,324,115.37 |
| 83 | 6.1.2.2.1 | **Placa Piso 2** | 8d | 2025-02-04 | 2025-02-12 |  | 0d | 16,370,026 |
| 84 | 6.1.2.2.1.1 | Armado de formaleta STEN Piso 2 | 2d | 2025-02-04 | 2025-02-05 | 81 | 0d | 3,600,000 |
| 85 | 6.1.2.2.1.2 | Armada de Aceros placa Piso 2 | 2d | 2025-02-05 | 2025-02-07 | 84 | 0d | 301,070 |
| 86 | 6.1.2.2.1.3 | Armado formaleta borde de placa P2 | 2d | 2025-02-05 | 2025-02-07 | 85SS | 0d | 800,000 |
| 87 | 6.1.2.2.1.4 | Armado, Forrado y Puesta de casetón recuperable P2 | 2d | 2025-02-07 | 2025-02-10 | 86 | 0d | 1,500,000 |
| 88 | 6.1.2.2.1.5 | Malla electrosoldada Piso 2 | 1d | 2025-02-10 | 2025-02-11 | 87 | 0d | 3,901,173 |
| 89 | 6.1.2.2.1.6 | Fundida de placa de Piso 2 concreto 28mpa | 1d | 2025-02-11 | 2025-02-12 | 88 | 0d | 6,267,783 |
| 90 | 6.1.2.2.2 | **Columnas Piso 2** | 3d | 2025-02-12 | 2025-02-15 |  | 0d | 30,954,089.37 |
| 91 | 6.1.2.2.2.1 | Armada de acero de refuerzo columnas Piso 2 | 1d | 2025-02-12 | 2025-02-13 | 89 | 0d | 21,706,076 |
| 92 | 6.1.2.2.2.2 | Armada de formaleta columnas Piso 2 | 1d | 2025-02-13 | 2025-02-14 | 91 | 0d | 3,600,000 |
| 93 | 6.1.2.2.2.3 | Fundida de columnas Piso 2 concreto 35mpa | 1d | 2025-02-14 | 2025-02-15 | 92 | 0d | 5,648,013.37 |
| 94 | 6.1.2.3 | **Estructura Piso 3** | 11d | 2025-02-15 | 2025-02-27 |  | 0d | 47,324,115.37 |
| 95 | 6.1.2.3.1 | **Placa Piso 3** | 8d | 2025-02-15 | 2025-02-25 |  | 0d | 16,370,026 |
| 96 | 6.1.2.3.1.1 | Armado de formaleta STEN Piso 3 | 2d | 2025-02-15 | 2025-02-18 | 93 | 0d | 3,600,000 |
| 97 | 6.1.2.3.1.2 | Armada de Aceros placa Piso 3 | 2d | 2025-02-18 | 2025-02-20 | 96 | 0d | 301,070 |
| 98 | 6.1.2.3.1.3 | Armado formaleta borde de placa P3 | 2d | 2025-02-18 | 2025-02-20 | 97SS | 0d | 800,000 |
| 99 | 6.1.2.3.1.4 | Armado, Forrado y Puesta de casetón recuperable P3 | 2d | 2025-02-20 | 2025-02-21 | 98 | 0d | 1,500,000 |
| 100 | 6.1.2.3.1.5 | Malla electrosoldada Piso 3 | 1d | 2025-02-22 | 2025-02-24 | 99 | 0d | 3,901,173 |
| 101 | 6.1.2.3.1.6 | Fundida de placa de Piso 3 concreto 28mpa | 1d | 2025-02-24 | 2025-02-25 | 100 | 0d | 6,267,783 |
| 102 | 6.1.2.3.2 | **Columnas Piso 3** | 3d | 2025-02-25 | 2025-02-27 |  | 0d | 30,954,089.37 |
| 103 | 6.1.2.3.2.1 | Armada de acero de refuerzo columnas Piso 3 | 1d | 2025-02-25 | 2025-02-26 | 101 | 0d | 21,706,076 |
| 104 | 6.1.2.3.2.2 | Armada de formaleta columnas Piso 3 | 1d | 2025-02-26 | 2025-02-26 | 103 | 0d | 3,600,000 |
| 105 | 6.1.2.3.2.3 | Fundida de columnas Piso 3 concreto 35mpa | 1d | 2025-02-27 | 2025-02-27 | 104 | 0d | 5,648,013.37 |

| ID | WBS | Task | Duration | Start | Finish | Predecessors | Total slack | Cost |
| --- | --- | --- | --- | --- | --- | --- | --- | --- |
| 106 | 6.1.2.4 | **Estructura Piso 4** | 11d | 2025-02-27 | 2025-03-12 |  | 0d | 47,324,115.37 |
| 107 | 6.1.2.4.1 | **Placa Piso 4** | 8d | 2025-02-27 | 2025-03-08 |  | 0d | 16,370,026 |
| 108 | 6.1.2.4.1.1 | Armado de formaleta STEN Piso 4 | 2d | 2025-02-27 | 2025-03-03 | 105 | 0d | 3,600,000 |
| 109 | 6.1.2.4.1.2 | Armada de Aceros placa Piso 4 | 2d | 2025-03-03 | 2025-03-04 | 108 | 0d | 301,070 |
| 110 | 6.1.2.4.1.3 | Armado formaleta borde de placa P4 | 2d | 2025-03-03 | 2025-03-04 | 109SS | 0d | 800,000 |
| 111 | 6.1.2.4.1.4 | Armado, Forrado y Puesta de casetón recuperable P4 | 2d | 2025-03-04 | 2025-03-06 | 110 | 0d | 1,500,000 |
| 112 | 6.1.2.4.1.5 | Malla electrosoldada Piso 4 | 1d | 2025-03-06 | 2025-03-07 | 111 | 0d | 3,901,173 |
| 113 | 6.1.2.4.1.6 | Fundida de placa de Piso 4 concreto 28mpa | 1d | 2025-03-07 | 2025-03-08 | 112 | 0d | 6,267,783 |
| 114 | 6.1.2.4.2 | **Columnas Piso 4** | 3d | 2025-03-08 | 2025-03-12 |  | 0d | 30,954,089.37 |
| 115 | 6.1.2.4.2.1 | Armada de acero de refuerzo columnas Piso 4 | 1d | 2025-03-08 | 2025-03-10 | 113 | 0d | 21,706,076 |
| 116 | 6.1.2.4.2.2 | Armada de formaleta columnas Piso 4 | 1d | 2025-03-10 | 2025-03-11 | 115 | 0d | 3,600,000 |
| 117 | 6.1.2.4.2.3 | Fundida de columnas Piso 4 concreto 35mpa | 1d | 2025-03-11 | 2025-03-12 | 116 | 0d | 5,648,013.37 |
| 118 | 6.1.2.5 | **Estructura Piso 5** | 11d | 2025-03-12 | 2025-03-26 |  | 0d | 47,324,115.37 |
| 119 | 6.1.2.5.1 | **Placa Piso 5** | 8d | 2025-03-12 | 2025-03-21 |  | 0d | 16,370,026 |
| 120 | 6.1.2.5.1.1 | Armado de formaleta STEN Piso 5 | 2d | 2025-03-12 | 2025-03-14 | 117 | 0d | 3,600,000 |
| 121 | 6.1.2.5.1.2 | Armada de Aceros placa Piso 5 | 2d | 2025-03-14 | 2025-03-17 | 120 | 0d | 301,070 |
| 122 | 6.1.2.5.1.3 | Armado formaleta borde de placa P5 | 2d | 2025-03-14 | 2025-03-17 | 121SS | 0d | 800,000 |
| 123 | 6.1.2.5.1.4 | Armado, Forrado y Puesta de casetón recuperable P5 | 2d | 2025-03-17 | 2025-03-19 | 122 | 0d | 1,500,000 |
| 124 | 6.1.2.5.1.5 | Malla electrosoldada Piso 5 | 1d | 2025-03-19 | 2025-03-20 | 123 | 0d | 3,901,173 |
| 125 | 6.1.2.5.1.6 | Fundida de placa de Piso 5 concreto 28mpa | 1d | 2025-03-20 | 2025-03-21 | 124 | 0d | 6,267,783 |
| 126 | 6.1.2.5.2 | **Columnas Piso 5** | 3d | 2025-03-21 | 2025-03-26 |  | 0d | 30,954,089.37 |
| 127 | 6.1.2.5.2.1 | Armada de acero de refuerzo columnas Piso 5 | 1d | 2025-03-21 | 2025-03-21 | 125 | 0d | 21,706,076 |
| 128 | 6.1.2.5.2.2 | Armada de formaleta columnas Piso 5 | 1d | 2025-03-22 | 2025-03-25 | 127 | 0d | 3,600,000 |
| 129 | 6.1.2.5.2.3 | Fundida de columnas Piso 5 concreto 35mpa | 1d | 2025-03-25 | 2025-03-26 | 128 | 0d | 5,648,013.37 |

| ID | WBS | Task | Duration | Start | Finish | Predecessors | Total slack | Cost |
| --- | --- | --- | --- | --- | --- | --- | --- | --- |
| 130 | 6.1.2.6 | **Estructura Piso 6** | 11d | 2025-03-26 | 2025-04-07 |  | 0d | 47,324,115.37 |
| 131 | 6.1.2.6.1 | **Placa Piso 6** | 8d | 2025-03-26 | 2025-04-03 |  | 0d | 16,370,026 |
| 132 | 6.1.2.6.1.1 | Armado de formaleta STEN Piso 6 | 2d | 2025-03-26 | 2025-03-27 | 129 | 0d | 3,600,000 |
| 133 | 6.1.2.6.1.2 | Armada de Aceros placa Piso 6 | 2d | 2025-03-28 | 2025-03-31 | 132 | 0d | 301,070 |
| 134 | 6.1.2.6.1.3 | Armado formaleta borde de placa P6 | 2d | 2025-03-28 | 2025-03-31 | 133SS | 0d | 800,000 |
| 135 | 6.1.2.6.1.4 | Armado, Forrado y Puesta de casetón recuperable P6 | 2d | 2025-03-31 | 2025-04-01 | 134 | 0d | 1,500,000 |
| 136 | 6.1.2.6.1.5 | Malla electrosoldada Piso 6 | 1d | 2025-04-02 | 2025-04-02 | 135 | 0d | 3,901,173 |
| 137 | 6.1.2.6.1.6 | Fundida de placa de Piso 6 concreto 28mpa | 1d | 2025-04-02 | 2025-04-03 | 136 | 0d | 6,267,783 |
| 138 | 6.1.2.6.2 | **Columnas Piso 6** | 3d | 2025-04-03 | 2025-04-07 |  | 0d | 30,954,089.37 |
| 139 | 6.1.2.6.2.1 | Armada de acero de refuerzo columnas Piso 6 | 1d | 2025-04-03 | 2025-04-04 | 137 | 0d | 21,706,076 |
| 140 | 6.1.2.6.2.2 | Armada de formaleta columnas Piso 6 | 1d | 2025-04-04 | 2025-04-05 | 139 | 0d | 3,600,000 |
| 141 | 6.1.2.6.2.3 | Fundida de columnas Piso 6 concreto 35mpa | 1d | 2025-04-07 | 2025-04-07 | 140 | 0d | 5,648,013.37 |
| 142 | 6.1.2.7 | **Estructura Piso 7** | 11d | 2025-04-07 | 2025-04-22 |  | 0d | 47,324,115.37 |
| 143 | 6.1.2.7.1 | **Placa Piso 7** | 8d | 2025-04-07 | 2025-04-16 |  | 0d | 16,370,026 |
| 144 | 6.1.2.7.1.1 | Armado de formaleta STEN Piso 7 | 2d | 2025-04-07 | 2025-04-09 | 141 | 0d | 3,600,000 |
| 145 | 6.1.2.7.1.2 | Armada de Aceros placa Piso 7 | 2d | 2025-04-09 | 2025-04-11 | 144 | 0d | 301,070 |
| 146 | 6.1.2.7.1.3 | Armado formaleta borde de placa P7 | 2d | 2025-04-09 | 2025-04-11 | 145SS | 0d | 800,000 |
| 147 | 6.1.2.7.1.4 | Armado, Forrado y Puesta de casetón recuperable P7 | 2d | 2025-04-11 | 2025-04-14 | 146 | 0d | 1,500,000 |
| 148 | 6.1.2.7.1.5 | Malla electrosoldada Piso 7 | 1d | 2025-04-14 | 2025-04-15 | 147 | 0d | 3,901,173 |
| 149 | 6.1.2.7.1.6 | Fundida de placa de Piso 7 concreto 28mpa | 1d | 2025-04-15 | 2025-04-16 | 148 | 0d | 6,267,783 |
| 150 | 6.1.2.7.2 | **Columnas Piso 7** | 3d | 2025-04-16 | 2025-04-22 |  | 0d | 30,954,089.37 |
| 151 | 6.1.2.7.2.1 | Armada de acero de refuerzo columnas Piso 7 | 1d | 2025-04-16 | 2025-04-19 | 149 | 0d | 21,706,076 |
| 152 | 6.1.2.7.2.2 | Armada de formaleta columnas Piso 7 | 1d | 2025-04-19 | 2025-04-21 | 151 | 0d | 3,600,000 |
| 153 | 6.1.2.7.2.3 | Fundida de columnas Piso 7 concreto 35mpa | 1d | 2025-04-21 | 2025-04-22 | 152 | 0d | 5,648,013.37 |

| ID | WBS | Task | Duration | Start | Finish | Predecessors | Total slack | Cost |
| --- | --- | --- | --- | --- | --- | --- | --- | --- |
| 154 | 6.1.2.8 | **Estructura Piso 8** | 11d | 2025-04-22 | 2025-05-06 |  | 0d | 47,324,115.37 |
| 155 | 6.1.2.8.1 | **Placa Piso 8** | 8d | 2025-04-22 | 2025-05-02 |  | 0d | 16,370,026 |
| 156 | 6.1.2.8.1.1 | Armado de formaleta STEN Piso 8 | 2d | 2025-04-22 | 2025-04-24 | 153 | 0d | 3,600,000 |
| 157 | 6.1.2.8.1.2 | Armada de Aceros placa Piso 8 | 2d | 2025-04-24 | 2025-04-26 | 156 | 0d | 301,070 |
| 158 | 6.1.2.8.1.3 | Armado formaleta borde de placa P8 | 2d | 2025-04-24 | 2025-04-26 | 157SS | 0d | 800,000 |
| 159 | 6.1.2.8.1.4 | Armado, Forrado y Puesta de casetón recuperable P8 | 2d | 2025-04-26 | 2025-04-29 | 158 | 0d | 1,500,000 |
| 160 | 6.1.2.8.1.5 | Malla electrosoldada Piso 8 | 1d | 2025-04-29 | 2025-04-30 | 159 | 0d | 3,901,173 |
| 161 | 6.1.2.8.1.6 | Fundida de placa de Piso 8 concreto 28mpa | 1d | 2025-04-30 | 2025-05-02 | 160 | 0d | 6,267,783 |
| 162 | 6.1.2.8.2 | **Columnas Piso 8** | 3d | 2025-05-02 | 2025-05-06 |  | 0d | 30,954,089.37 |
| 163 | 6.1.2.8.2.1 | Armada de acero de refuerzo columnas Piso 8 | 1d | 2025-05-02 | 2025-05-02 | 161 | 0d | 21,706,076 |
| 164 | 6.1.2.8.2.2 | Armada de formaleta columnas Piso 8 | 1d | 2025-05-03 | 2025-05-05 | 163 | 0d | 3,600,000 |
| 165 | 6.1.2.8.2.3 | Fundida de columnas Piso 8 concreto 35mpa | 1d | 2025-05-05 | 2025-05-06 | 164 | 0d | 5,648,013.37 |
| 166 | 6.1.2.9 | **Estructura Piso 9** | 11d | 2025-05-06 | 2025-05-17 |  | 0d | 47,324,115.37 |
| 167 | 6.1.2.9.1 | **Placa Piso 9** | 8d | 2025-05-06 | 2025-05-14 |  | 0d | 16,370,026 |
| 168 | 6.1.2.9.1.1 | Armado de formaleta STEN Piso 9 | 2d | 2025-05-06 | 2025-05-07 | 165 | 0d | 3,600,000 |
| 169 | 6.1.2.9.1.2 | Armada de Aceros placa Piso 9 | 2d | 2025-05-08 | 2025-05-09 | 168 | 0d | 301,070 |
| 170 | 6.1.2.9.1.3 | Armado formaleta borde de placa P9 | 2d | 2025-05-08 | 2025-05-09 | 169SS | 0d | 800,000 |
| 171 | 6.1.2.9.1.4 | Armado, Forrado y Puesta de casetón recuperable P9 | 2d | 2025-05-09 | 2025-05-12 | 170 | 0d | 1,500,000 |
| 172 | 6.1.2.9.1.5 | Malla electrosoldada Piso 9 | 1d | 2025-05-13 | 2025-05-13 | 171 | 0d | 3,901,173 |
| 173 | 6.1.2.9.1.6 | Fundida de placa de Piso 9 concreto 28mpa | 1d | 2025-05-13 | 2025-05-14 | 172 | 0d | 6,267,783 |
| 174 | 6.1.2.9.2 | **Columnas Piso 9** | 3d | 2025-05-14 | 2025-05-17 |  | 0d | 30,954,089.37 |
| 175 | 6.1.2.9.2.1 | Armada de acero de refuerzo columnas Piso 9 | 1d | 2025-05-14 | 2025-05-15 | 173 | 0d | 21,706,076 |
| 176 | 6.1.2.9.2.2 | Armada de formaleta columnas Piso 9 | 1d | 2025-05-15 | 2025-05-16 | 175 | 0d | 3,600,000 |
| 177 | 6.1.2.9.2.3 | Fundida de columnas Piso 9 concreto 35mpa | 1d | 2025-05-16 | 2025-05-17 | 176 | 0d | 5,648,013.37 |

| ID | WBS | Task | Duration | Start | Finish | Predecessors | Total slack | Free slack | Cost |
| --- | --- | --- | --- | --- | --- | --- | --- | --- | --- |
| 178 | 6.1.2.10 | **Estructura Piso 10** | 11d | 2025-05-17 | 2025-05-30 |  | 0d |  | 47,324,115.37 |
| 179 | 6.1.2.10.1 | **Placa Piso 10** | 8d | 2025-05-17 | 2025-05-27 |  | 0d |  | 16,370,026 |
| 180 | 6.1.2.10.1.1 | Armado de formaleta STEN Piso 10 | 2d | 2025-05-17 | 2025-05-20 | 177 | 0d |  | 3,600,000 |
| 181 | 6.1.2.10.1.2 | Armada de Aceros placa Piso 10 | 2d | 2025-05-20 | 2025-05-22 | 180 | 0d |  | 301,070 |
| 182 | 6.1.2.10.1.3 | Armado formaleta borde de placa P10 | 2d | 2025-05-20 | 2025-05-22 | 181SS | 0d |  | 800,000 |
| 183 | 6.1.2.10.1.4 | Armado, Forrado y Puesta de casetón recuperable P10 | 2d | 2025-05-22 | 2025-05-24 | 182 | 0d |  | 1,500,000 |
| 184 | 6.1.2.10.1.5 | Malla electrosoldada Piso 10 | 1d | 2025-05-24 | 2025-05-26 | 183 | 0d |  | 3,901,173 |
| 185 | 6.1.2.10.1.6 | Fundida de placa de Piso 10 concreto 28mpa | 1d | 2025-05-26 | 2025-05-27 | 184 | 0d |  | 6,267,783 |
| 186 | 6.1.2.10.2 | **Columnas Piso 10** | 3d | 2025-05-27 | 2025-05-30 |  | 134d |  | 30,954,089.37 |
| 187 | 6.1.2.10.2.1 | Armada de acero de refuerzo columnas Piso 10 | 1d | 2025-05-27 | 2025-05-28 | 185 | 134d | 0d | 21,706,076 |
| 188 | 6.1.2.10.2.2 | Armada de formaleta columnas Piso 10 | 1d | 2025-05-28 | 2025-05-29 | 187 | 134d | 0d | 3,600,000 |
| 189 | 6.1.2.10.2.3 | Fundida de columnas Piso 10 concreto 35mpa | 1d | 2025-05-29 | 2025-05-30 | 188 | 134d | 0d | 5,648,013.37 |
| 190 | 6.1.2.11 | **Estructura Terraza** | 14d | 2025-05-30 | 2025-06-16 |  | 134d |  | 39,279,509 |
| 191 | 6.1.2.11.1 | **Placa Terraza** | 8d | 2025-05-30 | 2025-06-10 |  | 134d |  | 16,370,026 |
| 192 | 6.1.2.11.1.1 | Armado de formaleta STEN Terraza | 2d | 2025-05-30 | 2025-06-03 | 189 | 134d | 0d | 3,600,000 |
| 193 | 6.1.2.11.1.2 | Armada de Aceros placa Terraza | 2d | 2025-06-03 | 2025-06-05 | 192 | 134d | 0d | 301,070 |
| 194 | 6.1.2.11.1.3 | Armado formaleta borde de placa Terraza | 2d | 2025-06-03 | 2025-06-05 | 193SS | 134d | 0d | 800,000 |
| 195 | 6.1.2.11.1.4 | Armado, Forrado y Puesta de casetón recuperable T | 2d | 2025-06-05 | 2025-06-06 | 194 | 134d | 0d | 1,500,000 |
| 196 | 6.1.2.11.1.5 | Malla electrosoldada Terraza | 1d | 2025-06-06 | 2025-06-09 | 195 | 134d | 0d | 3,901,173 |
| 197 | 6.1.2.11.1.6 | Fundida de placa de Terraza concreto 28mpa | 1d | 2025-06-09 | 2025-06-10 | 196 | 134d | 0d | 6,267,783 |
| 198 | 6.1.2.11.2 | **Muros Cuarto de Máquinas** | 2d | 2025-06-10 | 2025-06-11 |  | 134d |  | 8,300,000 |
| 199 | 6.1.2.11.2.1 | Muro en mamposteria confinada | 2d | 2025-06-10 | 2025-06-11 | 197 | 134d | 0d | 5,100,000 |
| 200 | 6.1.2.11.2.2 | Columnetas | 2d | 2025-06-10 | 2025-06-11 | 199SS | 134d | 0d | 3,200,000 |
| 201 | 6.1.2.11.3 | **Placa Cubierta Cuarto de Máquinas** | 4d | 2025-06-11 | 2025-06-16 |  | 134d |  | 14,609,483 |
| 202 | 6.1.2.11.3.1 | Armado de formaleta entrepiso | 1d | 2025-06-11 | 2025-06-12 | 200 | 134d | 0d | 2,450,000 |
| 203 | 6.1.2.11.3.2 | Armada de Aceros placa Cubierta | 1d | 2025-06-12 | 2025-06-13 | 202 | 134d | 0d | 3,654,700 |
| 204 | 6.1.2.11.3.3 | Armado formaleta borde de placa Cubierta | 1d | 2025-06-12 | 2025-06-13 | 203SS | 134d | 0d | 690,000 |
| 205 | 6.1.2.11.3.4 | Armado de refuerzo placa de Cubierta | 1d | 2025-06-13 | 2025-06-14 | 204 | 134d | 0d | 1,547,000 |
| 206 | 6.1.2.11.3.5 | Fundida de placa de Cubierta concreto 28mpa | 1d | 2025-06-16 | 2025-06-16 | 205 | 134d | 0d | 6,267,783 |

| ID | WBS | Task | Duration | Start | Finish | Predecessors | Total slack | Free slack | Cost |
| --- | --- | --- | --- | --- | --- | --- | --- | --- | --- |
| 207 | 6.1.2.12 | **Escaleras** | 106d | 2025-02-27 | 2025-07-05 |  | 152d |  | 102,690,940 |
| 208 | 6.1.2.12.1 | **Escalera Piso 1** | 7d | 2025-02-27 | 2025-03-07 |  | 251d |  | 10,269,094 |
| 209 | 6.1.2.12.1.1 | Armado de formaleta escalera P1 | 3d | 2025-02-27 | 2025-03-03 | 89FS+14d | 251d | 0d | 3,080,728 |
| 210 | 6.1.2.12.1.2 | Colocación refuerzo escalera P1 | 3d | 2025-03-04 | 2025-03-06 | 209 | 251d | 0d | 1,026,909 |
| 211 | 6.1.2.12.1.3 | Fundida de Escalera P1 concreto 28mpa | 1d | 2025-03-06 | 2025-03-07 | 210 | 251d |  | 6,161,457 |
| 212 | 6.1.2.12.2 | **Escalera Piso 2** | 7d | 2025-03-12 | 2025-03-20 |  | 240d |  | 10,269,094 |
| 213 | 6.1.2.12.2.1 | Armado de formaleta escalera P2 | 3d | 2025-03-12 | 2025-03-15 | 101FS+14d | 240d | 0d | 3,080,728 |
| 214 | 6.1.2.12.2.2 | Colocación refuerzo escalera P2 | 3d | 2025-03-15 | 2025-03-19 | 213 | 240d | 0d | 1,026,909 |
| 215 | 6.1.2.12.2.3 | Fundida de Escalera P2 concreto 28mpa | 1d | 2025-03-19 | 2025-03-20 | 214 | 240d |  | 6,161,457 |
| 216 | 6.1.2.12.3 | **Escalera Piso 3** | 7d | 2025-03-26 | 2025-04-02 |  | 229d |  | 10,269,094 |
| 217 | 6.1.2.12.3.1 | Armado de formaleta escalera P3 | 3d | 2025-03-26 | 2025-03-28 | 113FS+14d | 229d | 0d | 3,080,728 |
| 218 | 6.1.2.12.3.2 | Colocación refuerzo escalera P3 | 3d | 2025-03-28 | 2025-04-01 | 217 | 229d | 0d | 1,026,909 |
| 219 | 6.1.2.12.3.3 | Fundida de Escalera P3 concreto 28mpa | 1d | 2025-04-02 | 2025-04-02 | 218 | 229d |  | 6,161,457 |
| 220 | 6.1.2.12.4 | **Escalera Piso 4** | 7d | 2025-04-07 | 2025-04-15 |  | 218d |  | 10,269,094 |
| 221 | 6.1.2.12.4.1 | Armado de formaleta escalera P4 | 3d | 2025-04-07 | 2025-04-10 | 125FS+14d | 218d | 0d | 3,080,728 |
| 222 | 6.1.2.12.4.2 | Colocación refuerzo escalera P4 | 3d | 2025-04-10 | 2025-04-14 | 221 | 218d | 0d | 1,026,909 |
| 223 | 6.1.2.12.4.3 | Fundida de Escalera P4 concreto 28mpa | 1d | 2025-04-14 | 2025-04-15 | 222 | 218d |  | 6,161,457 |
| 224 | 6.1.2.12.5 | **Escalera Piso 5** | 7d | 2025-04-22 | 2025-04-30 |  | 207d |  | 10,269,094 |
| 225 | 6.1.2.12.5.1 | Armado de formaleta escalera P5 | 3d | 2025-04-22 | 2025-04-25 | 137FS+14d | 207d | 0d | 3,080,728 |
| 226 | 6.1.2.12.5.2 | Colocación refuerzo escalera P5 | 3d | 2025-04-25 | 2025-04-29 | 225 | 207d | 0d | 1,026,909 |
| 227 | 6.1.2.12.5.3 | Fundida de Escalera P5 concreto 28mpa | 1d | 2025-04-29 | 2025-04-30 | 226 | 207d |  | 6,161,457 |
| 228 | 6.1.2.12.6 | **Escalera Piso 6** | 7d | 2025-05-06 | 2025-05-13 |  | 196d |  | 10,269,094 |
| 229 | 6.1.2.12.6.1 | Armado de formaleta escalera P6 | 3d | 2025-05-06 | 2025-05-08 | 149FS+14d | 196d | 0d | 3,080,728 |
| 230 | 6.1.2.12.6.2 | Colocación refuerzo escalera P6 | 3d | 2025-05-08 | 2025-05-12 | 229 | 196d | 0d | 1,026,909 |
| 231 | 6.1.2.12.6.3 | Fundida de Escalera P6 concreto 28mpa | 1d | 2025-05-13 | 2025-05-13 | 230 | 196d |  | 6,161,457 |

| ID | WBS | Task | Duration | Start | Finish | Predecessors | Total slack | Free slack | Cost |
| --- | --- | --- | --- | --- | --- | --- | --- | --- | --- |
| 232 | 6.1.2.12.7 | **Escalera Piso 7** | 7d | 2025-05-17 | 2025-05-26 |  | 185d |  | 10,269,094 |
| 233 | 6.1.2.12.7.1 | Armado de formaleta escalera P7 | 3d | 2025-05-17 | 2025-05-21 | 161FS+14d | 185d | 0d | 3,080,728 |
| 234 | 6.1.2.12.7.2 | Colocación refuerzo escalera P7 | 3d | 2025-05-21 | 2025-05-24 | 233 | 185d | 0d | 1,026,909 |
| 235 | 6.1.2.12.7.3 | Fundida de Escalera P7 concreto 28mpa | 1d | 2025-05-24 | 2025-05-26 | 234 | 185d |  | 6,161,457 |
| 236 | 6.1.2.12.8 | **Escalera Piso 8** | 7d | 2025-05-30 | 2025-06-09 |  | 174d |  | 10,269,094 |
| 237 | 6.1.2.12.8.1 | Armado de formaleta escalera P8 | 3d | 2025-05-30 | 2025-06-04 | 173FS+14d | 174d | 0d | 3,080,728 |
| 238 | 6.1.2.12.8.2 | Colocación refuerzo escalera P8 | 3d | 2025-06-04 | 2025-06-06 | 237 | 174d | 0d | 1,026,909 |
| 239 | 6.1.2.12.8.3 | Fundida de Escalera P8 concreto 28mpa | 1d | 2025-06-06 | 2025-06-09 | 238 | 174d |  | 6,161,457 |
| 240 | 6.1.2.12.9 | **Escalera Piso 9** | 7d | 2025-06-12 | 2025-06-20 |  | 163d |  | 10,269,094 |
| 241 | 6.1.2.12.9.1 | Armado de formaleta escalera P9 | 3d | 2025-06-12 | 2025-06-16 | 185FS+14d | 163d | 0d | 3,080,728 |
| 242 | 6.1.2.12.9.2 | Colocación refuerzo escalera P9 | 3d | 2025-06-16 | 2025-06-19 | 241 | 163d | 0d | 1,026,909 |
| 243 | 6.1.2.12.9.3 | Fundida de Escalera P9 concreto 28mpa | 1d | 2025-06-19 | 2025-06-20 | 242 | 163d |  | 6,161,457 |
| 244 | 6.1.2.12.10 | **Escalera Piso 10** | 7d | 2025-06-26 | 2025-07-05 |  | 152d |  | 10,269,094 |
| 245 | 6.1.2.12.10.1 | Armado de formaleta escalera P10 | 3d | 2025-06-26 | 2025-07-01 | 197FS+14d | 152d | 0d | 3,080,728 |
| 246 | 6.1.2.12.10.2 | Colocación refuerzo escalera P10 | 3d | 2025-07-01 | 2025-07-04 | 245 | 152d | 0d | 1,026,909 |
| 247 | 6.1.2.12.10.3 | Fundida de Escalera P10 concreto 28mpa | 1d | 2025-07-04 | 2025-07-05 | 246 | 152d |  | 6,161,457 |
| 248 | 6.2 | **Obra gris** | 170d | 2025-02-03 | 2025-08-22 |  | 102d |  | 227,645,094.9 |
| 249 | 6.2.1 | **Mampostería** | 134d | 2025-03-04 | 2025-08-11 |  | 75d |  | 133,300,464.53 |
| 250 | 6.2.1.1 | **Muro en bloque de concreto** | 104d | 2025-03-04 | 2025-07-07 |  | 76d |  | 20,926,706.9 |
| 251 | 6.2.1.1.1 | Muro en bloque de concreto P1 | 5d | 2025-03-04 | 2025-03-08 | 77FS+28d | 76d | 0d | 2,092,670.69 |
| 252 | 6.2.1.1.2 | Muro en bloque de concreto P2 | 5d | 2025-03-15 | 2025-03-21 | 89FS+28d | 170d | 0d | 2,092,670.69 |
| 253 | 6.2.1.1.3 | Muro en bloque de concreto P3 | 5d | 2025-03-28 | 2025-04-03 | 101FS+28d | 159d | 0d | 2,092,670.69 |
| 254 | 6.2.1.1.4 | Muro en bloque de concreto P4 | 5d | 2025-04-10 | 2025-04-16 | 113FS+28d | 148d | 0d | 2,092,670.69 |
| 255 | 6.2.1.1.5 | Muro en bloque de concreto P5 | 5d | 2025-04-25 | 2025-05-02 | 125FS+28d | 137d | 0d | 2,092,670.69 |
| 256 | 6.2.1.1.6 | Muro en bloque de concreto P6 | 5d | 2025-05-08 | 2025-05-14 | 137FS+28d | 126d | 0d | 2,092,670.69 |
| 257 | 6.2.1.1.7 | Muro en bloque de concreto P7 | 5d | 2025-05-21 | 2025-05-27 | 149FS+28d | 115d | 0d | 2,092,670.69 |
| 258 | 6.2.1.1.8 | Muro en bloque de concreto P8 | 5d | 2025-06-04 | 2025-06-10 | 161FS+28d | 104d | 0d | 2,092,670.69 |
| 259 | 6.2.1.1.9 | Muro en bloque de concreto P9 | 5d | 2025-06-16 | 2025-06-21 | 173FS+28d | 93d | 0d | 2,092,670.69 |
| 260 | 6.2.1.1.10 | Muro en bloque de concreto P10 | 5d | 2025-07-01 | 2025-07-07 | 185FS+28d | 0d |  | 2,092,670.69 |

| ID | WBS | Task | Duration | Start | Finish | Predecessors | Total slack | Free slack | Cost |
| --- | --- | --- | --- | --- | --- | --- | --- | --- | --- |
| 261 | 6.2.1.2 | **Muro en panelco** | 105d | 2025-03-08 | 2025-07-14 |  | 76d |  | 90,524,207.6 |
| 262 | 6.2.1.2.1 | Muro en panelco P1 | 6d | 2025-03-08 | 2025-03-15 | 251 | 76d | 0d | 9,052,420.76 |
| 263 | 6.2.1.2.2 | Muro en panelco P2 | 6d | 2025-03-21 | 2025-03-28 | 252 | 170d | 0d | 9,052,420.76 |
| 264 | 6.2.1.2.3 | Muro en panelco P3 | 6d | 2025-04-03 | 2025-04-10 | 253 | 159d | 0d | 9,052,420.76 |
| 265 | 6.2.1.2.4 | Muro en panelco P4 | 6d | 2025-04-16 | 2025-04-25 | 254 | 148d | 0d | 9,052,420.76 |
| 266 | 6.2.1.2.5 | Muro en panelco P5 | 6d | 2025-05-02 | 2025-05-08 | 255 | 137d | 0d | 9,052,420.76 |
| 267 | 6.2.1.2.6 | Muro en panelco P6 | 6d | 2025-05-14 | 2025-05-21 | 256 | 126d | 0d | 9,052,420.76 |
| 268 | 6.2.1.2.7 | Muro en panelco P7 | 6d | 2025-05-27 | 2025-06-04 | 257 | 115d | 0d | 9,052,420.76 |
| 269 | 6.2.1.2.8 | Muro en panelco P8 | 6d | 2025-06-10 | 2025-06-16 | 258 | 104d | 0d | 9,052,420.76 |
| 270 | 6.2.1.2.9 | Muro en panelco P9 | 6d | 2025-06-21 | 2025-07-01 | 259 | 93d | 0d | 9,052,420.76 |
| 271 | 6.2.1.2.10 | Muro en panelco P10 | 6d | 2025-07-07 | 2025-07-14 | 260 | 0d |  | 9,052,420.76 |
| 272 | 6.2.1.3 | **Muro en ladrillo prensado** | 113d | 2025-03-28 | 2025-08-11 |  | 75d |  | 21,849,550.03 |
| 273 | 6.2.1.3.1 | Muro en ladrillo prensado P1 | 7d | 2025-03-28 | 2025-04-04 | 262FS+10d | 143d | 0d | 1,986,322.73 |
| 274 | 6.2.1.3.2 | Muro en ladrillo prensado P2 | 7d | 2025-04-09 | 2025-04-19 | 263FS+10d | 170d | 0d | 1,986,322.73 |
| 275 | 6.2.1.3.3 | Muro en ladrillo prensado P3 | 7d | 2025-04-24 | 2025-05-02 | 264FS+10d | 159d | 0d | 1,986,322.73 |
| 276 | 6.2.1.3.4 | Muro en ladrillo prensado P4 | 7d | 2025-05-08 | 2025-05-15 | 265FS+10d | 148d | 0d | 1,986,322.73 |
| 277 | 6.2.1.3.5 | Muro en ladrillo prensado P5 | 7d | 2025-05-20 | 2025-05-28 | 266FS+10d | 137d | 0d | 1,986,322.73 |
| 278 | 6.2.1.3.6 | Muro en ladrillo prensado P6 | 7d | 2025-06-03 | 2025-06-10 | 267FS+10d | 126d | 0d | 1,986,322.73 |
| 279 | 6.2.1.3.7 | Muro en ladrillo prensado P7 | 7d | 2025-06-16 | 2025-06-24 | 268FS+10d | 115d | 0d | 1,986,322.73 |
| 280 | 6.2.1.3.8 | Muro en ladrillo prensado P8 | 7d | 2025-06-28 | 2025-07-08 | 269FS+10d | 104d | 0d | 1,986,322.73 |
| 281 | 6.2.1.3.9 | Muro en ladrillo prensado P9 | 7d | 2025-07-11 | 2025-07-19 | 270FS+10d | 93d | 0d | 1,986,322.73 |
| 282 | 6.2.1.3.10 | Muro en ladrillo prensado P10 | 7d | 2025-07-24 | 2025-08-01 | 271FS+10d | 0d |  | 1,986,322.73 |
| 283 | 6.2.1.3.11 | Muro en ladrillo prensado Terraza | 7d | 2025-08-01 | 2025-08-11 | 282 | 0d |  | 1,986,322.73 |
| 284 | 6.2.2 | **Pañetes** | 113d | 2025-04-04 | 2025-08-19 |  | 105d |  | 41,932,403.28 |
| 285 | 6.2.2.1 | **Pañete sobre muro** | 111d | 2025-04-04 | 2025-08-15 |  | 75d |  | 30,713,756.28 |
| 286 | 6.2.2.1.1 | Pañete sobre muro P1 | 5d | 2025-04-04 | 2025-04-10 | 273 | 143d | 0d | 2,559,479.69 |
| 287 | 6.2.2.1.2 | Pañete sobre muro P2 | 5d | 2025-04-19 | 2025-04-25 | 274 | 170d | 0d | 2,559,479.69 |
| 288 | 6.2.2.1.3 | Pañete sobre muro P3 | 5d | 2025-05-03 | 2025-05-08 | 275 | 159d | 0d | 2,559,479.69 |
| 289 | 6.2.2.1.4 | Pañete sobre muro P4 | 5d | 2025-05-15 | 2025-05-21 | 276 | 148d | 0d | 2,559,479.69 |
| 290 | 6.2.2.1.5 | Pañete sobre muro P5 | 5d | 2025-05-28 | 2025-06-04 | 277 | 137d | 0d | 2,559,479.69 |
| 291 | 6.2.2.1.6 | Pañete sobre muro P6 | 5d | 2025-06-11 | 2025-06-16 | 278 | 126d | 0d | 2,559,479.69 |
| 292 | 6.2.2.1.7 | Pañete sobre muro P7 | 5d | 2025-06-24 | 2025-07-01 | 279 | 115d | 0d | 2,559,479.69 |
| 293 | 6.2.2.1.8 | Pañete sobre muro P8 | 5d | 2025-07-08 | 2025-07-14 | 280 | 104d | 0d | 2,559,479.69 |
| 294 | 6.2.2.1.9 | Pañete sobre muro P9 | 5d | 2025-07-21 | 2025-07-25 | 281 | 93d | 0d | 2,559,479.69 |
| 295 | 6.2.2.1.10 | Pañete sobre muro P10 | 5d | 2025-08-01 | 2025-08-08 | 282 | 50d | 0d | 2,559,479.69 |
| 296 | 6.2.2.1.11 | Pañete sobre muro Terraza | 5d | 2025-08-11 | 2025-08-15 | 283 | 0d |  | 2,559,479.69 |
| 297 | 6.2.2.1.12 | Pañete Punto Fijo | 30d | 2025-07-11 | 2025-08-15 | 296FF | 26d | 0d | 2,559,479.69 |

| ID | WBS | Task | Duration | Start | Finish | Predecessors | Total slack | Free slack | Cost |
| --- | --- | --- | --- | --- | --- | --- | --- | --- | --- |
| 298 | 6.2.2.2 | **Filos y dilataciones** | 108d | 2025-04-10 | 2025-08-19 |  | 105d |  | 11,218,647 |
| 299 | 6.2.2.2.1 | Filos y dilataciones P1 | 2d | 2025-04-10 | 2025-04-12 | 286 | 211d | 0d | 1,019,877 |
| 300 | 6.2.2.2.2 | Filos y dilataciones P2 | 2d | 2025-04-25 | 2025-04-28 | 287 | 200d | 0d | 1,019,877 |
| 301 | 6.2.2.2.3 | Filos y dilataciones P3 | 2d | 2025-05-08 | 2025-05-12 | 288 | 189d | 0d | 1,019,877 |
| 302 | 6.2.2.2.4 | Filos y dilataciones P4 | 2d | 2025-05-21 | 2025-05-23 | 289 | 178d | 0d | 1,019,877 |
| 303 | 6.2.2.2.5 | Filos y dilataciones P5 | 2d | 2025-06-04 | 2025-06-05 | 290 | 167d | 0d | 1,019,877 |
| 304 | 6.2.2.2.6 | Filos y dilataciones P6 | 2d | 2025-06-16 | 2025-06-18 | 291 | 156d | 0d | 1,019,877 |
| 305 | 6.2.2.2.7 | Filos y dilataciones P7 | 2d | 2025-07-01 | 2025-07-03 | 292 | 145d | 0d | 1,019,877 |
| 306 | 6.2.2.2.8 | Filos y dilataciones P8 | 2d | 2025-07-14 | 2025-07-15 | 293 | 134d | 0d | 1,019,877 |
| 307 | 6.2.2.2.9 | Filos y dilataciones P9 | 2d | 2025-07-25 | 2025-07-28 | 294 | 123d | 0d | 1,019,877 |
| 308 | 6.2.2.2.10 | Filos y dilataciones P10 | 2d | 2025-08-08 | 2025-08-11 | 295 | 112d | 0d | 1,019,877 |
| 309 | 6.2.2.2.11 | Filos y dilataciones Terraza | 2d | 2025-08-15 | 2025-08-19 | 296 | 0d |  | 1,019,877 |
| 310 | 6.2.3 | **Impermeabilizaciones** | 170d | 2025-02-03 | 2025-08-22 |  | 111d |  | 23,024,725 |
| 311 | 6.2.3.1 | Impermeabilización sobre placa | 5d | 2025-07-21 | 2025-07-25 | 206FS+28d | 134d |  | 14,204,725 |
| 312 | 6.2.3.2 | Impermeabilización sobre muro | 5d | 2025-08-15 | 2025-08-22 | 296 | 111d |  | 3,720,000 |
| 313 | 6.2.3.3 | Impermeabilización tanque | 5d | 2025-02-03 | 2025-02-07 | 60FS+28d | 276d |  | 5,100,000 |
| 314 | 6.2.4 | **Pisos** | 111d | 2025-04-10 | 2025-08-22 |  | 80d |  | 29,387,502.09 |
| 315 | 6.2.4.1 | **Sobrepisos** | 109d | 2025-04-10 | 2025-08-20 |  | 80d |  | 19,519,502.09 |
| 316 | 6.2.4.1.1 | Sobrepiso P1 | 3d | 2025-04-10 | 2025-04-14 | 286 | 143d | 0d | 1,774,500.19 |
| 317 | 6.2.4.1.2 | Sobrepiso P2 | 3d | 2025-04-25 | 2025-04-29 | 287 | 170d | 0d | 1,774,500.19 |
| 318 | 6.2.4.1.3 | Sobrepiso P3 | 3d | 2025-05-08 | 2025-05-12 | 288 | 159d | 0d | 1,774,500.19 |
| 319 | 6.2.4.1.4 | Sobrepiso P4 | 3d | 2025-05-21 | 2025-05-24 | 289 | 148d | 0d | 1,774,500.19 |
| 320 | 6.2.4.1.5 | Sobrepiso P5 | 3d | 2025-06-04 | 2025-06-06 | 290 | 137d | 0d | 1,774,500.19 |
| 321 | 6.2.4.1.6 | Sobrepiso P6 | 3d | 2025-06-16 | 2025-06-19 | 291 | 126d | 0d | 1,774,500.19 |
| 322 | 6.2.4.1.7 | Sobrepiso P7 | 3d | 2025-07-01 | 2025-07-04 | 292 | 115d | 0d | 1,774,500.19 |
| 323 | 6.2.4.1.8 | Sobrepiso P8 | 3d | 2025-07-14 | 2025-07-16 | 293 | 104d | 0d | 1,774,500.19 |
| 324 | 6.2.4.1.9 | Sobrepiso P9 | 3d | 2025-07-25 | 2025-07-29 | 294 | 93d | 0d | 1,774,500.19 |
| 325 | 6.2.4.1.10 | Sobrepiso P10 | 3d | 2025-08-08 | 2025-08-12 | 295 | 50d | 0d | 1,774,500.19 |
| 326 | 6.2.4.1.11 | Sobrepiso Terraza | 3d | 2025-08-15 | 2025-08-20 | 296 | 80d | 0d | 1,774,500.19 |

| ID | WBS | Task | Duration | Start | Finish | Predecessors | Total slack | Free slack | Cost |
| --- | --- | --- | --- | --- | --- | --- | --- | --- | --- |
| 327 | 6.2.4.2 | **Alistado escaleras** | 97d | 2025-04-29 | 2025-08-22 |  | 80d |  | 9,868,000 |
| 328 | 6.2.4.2.1 | Alistado escalera P1 | 2d | 2025-04-29 | 2025-05-02 | 317 | 175d | 0d | 986,800 |
| 329 | 6.2.4.2.2 | Alistado escalera P2 | 2d | 2025-05-13 | 2025-05-14 | 318 | 164d | 0d | 986,800 |
| 330 | 6.2.4.2.3 | Alistado escalera P3 | 2d | 2025-05-24 | 2025-05-27 | 319 | 153d | 0d | 986,800 |
| 331 | 6.2.4.2.4 | Alistado escalera P4 | 2d | 2025-06-06 | 2025-06-10 | 320 | 142d | 0d | 986,800 |
| 332 | 6.2.4.2.5 | Alistado escalera P5 | 2d | 2025-06-19 | 2025-06-21 | 321 | 131d | 0d | 986,800 |
| 333 | 6.2.4.2.6 | Alistado escalera P6 | 2d | 2025-07-04 | 2025-07-07 | 322 | 120d | 0d | 986,800 |
| 334 | 6.2.4.2.7 | Alistado escalera P7 | 2d | 2025-07-16 | 2025-07-18 | 323 | 109d | 0d | 986,800 |
| 335 | 6.2.4.2.8 | Alistado escalera P8 | 2d | 2025-07-29 | 2025-07-31 | 324 | 98d | 0d | 986,800 |
| 336 | 6.2.4.2.9 | Alistado escalera P9 | 2d | 2025-08-12 | 2025-08-13 | 325 | 87d | 0d | 986,800 |
| 337 | 6.2.4.2.10 | Alistado escalera P10 | 2d | 2025-08-20 | 2025-08-22 | 326 | 80d | 0d | 986,800 |
| 338 | 6.3 | **Instalaciones** | 249d | 2025-01-15 | 2025-11-04 |  | 48d |  | 478,152,725 |
| 339 | 6.3.1 | **Instalaciones hidraúlicas** | 122d | 2025-03-08 | 2025-08-01 |  | 76d |  | 97,255,524.99 |
| 340 | 6.3.1.1 | Prolongación de tuberías verticales | 106d | 2025-03-08 | 2025-07-15 | 262SS | 76d | 0d | 7,481,194.23 |
| 341 | 6.3.1.2 | **Prolongación de tuberías en pisos** | 103d | 2025-03-15 | 2025-07-17 |  | 128d |  | 74,811,942.3 |
| 342 | 6.3.1.2.1 | Prolongación de tuberías Piso 1 | 4d | 2025-03-15 | 2025-03-20 | 262 | 227d | 0d | 7,481,194.23 |
| 343 | 6.3.1.2.2 | Prolongación de tuberías Piso 2 | 4d | 2025-03-28 | 2025-04-02 | 263 | 216d | 0d | 7,481,194.23 |
| 344 | 6.3.1.2.3 | Prolongación de tuberías Piso 3 | 4d | 2025-04-10 | 2025-04-15 | 264 | 205d | 0d | 7,481,194.23 |
| 345 | 6.3.1.2.4 | Prolongación de tuberías Piso 4 | 4d | 2025-04-25 | 2025-04-30 | 265 | 194d | 0d | 7,481,194.23 |
| 346 | 6.3.1.2.5 | Prolongación de tuberías Piso 5 | 4d | 2025-05-08 | 2025-05-13 | 266 | 183d | 0d | 7,481,194.23 |
| 347 | 6.3.1.2.6 | Prolongación de tuberías Piso 6 | 4d | 2025-05-21 | 2025-05-26 | 267 | 172d | 0d | 7,481,194.23 |
| 348 | 6.3.1.2.7 | Prolongación de tuberías Piso 7 | 4d | 2025-06-04 | 2025-06-09 | 268 | 161d | 0d | 7,481,194.23 |
| 349 | 6.3.1.2.8 | Prolongación de tuberías Piso 8 | 4d | 2025-06-16 | 2025-06-20 | 269 | 150d | 0d | 7,481,194.23 |
| 350 | 6.3.1.2.9 | Prolongación de tuberías Piso 9 | 4d | 2025-07-01 | 2025-07-05 | 270 | 139d | 0d | 7,481,194.23 |
| 351 | 6.3.1.2.10 | Prolongación de tuberías Piso 10 | 4d | 2025-07-14 | 2025-07-17 | 271 | 124d | 0d | 7,481,194.23 |
| 352 | 6.3.1.3 | Instalación de Cajillas de medidores | 5d | 2025-07-17 | 2025-07-23 | 351 | 128d | 0d | 7,481,194.23 |
| 353 | 6.3.1.4 | Instalación de equipos de presión | 8d | 2025-07-23 | 2025-08-01 | 352 | 128d |  | 7,481,194.23 |

| ID | WBS | Task | Duration | Start | Finish | Predecessors | Total slack | Free slack | Cost |
| --- | --- | --- | --- | --- | --- | --- | --- | --- | --- |
| 354 | 6.3.2 | **Instalaciones sanitarias** | 160d | 2025-01-15 | 2025-07-22 |  | 137d |  | 47,657,199.96 |
| 355 | 6.3.2.1 | Prolongación desagües cimentación | 7d | 2025-01-15 | 2025-01-23 | 69SF | 290d |  | 3,971,433.33 |
| 356 | 6.3.2.2 | Instalación verticales sanitarias | 106d | 2025-03-08 | 2025-07-15 | 340SS | 144d |  | 3,971,433.33 |
| 357 | 6.3.2.3 | **Instalación de tuberías sanitarias en pisos** | 103d | 2025-03-20 | 2025-07-22 |  | 128d |  | 39,714,333.3 |
| 358 | 6.3.2.3.1 | Instalación de tuberías sanitarias Piso 1 | 4d | 2025-03-20 | 2025-03-26 | 342 | 227d | 0d | 3,971,433.33 |
| 359 | 6.3.2.3.2 | Instalación de tuberías sanitarias Piso 2 | 4d | 2025-04-02 | 2025-04-07 | 343 | 216d | 0d | 3,971,433.33 |
| 360 | 6.3.2.3.3 | Instalación de tuberías sanitarias Piso 3 | 4d | 2025-04-15 | 2025-04-22 | 344 | 205d | 0d | 3,971,433.33 |
| 361 | 6.3.2.3.4 | Instalación de tuberías sanitarias Piso 4 | 4d | 2025-04-30 | 2025-05-06 | 345 | 194d | 0d | 3,971,433.33 |
| 362 | 6.3.2.3.5 | Instalación de tuberías sanitarias Piso 5 | 4d | 2025-05-13 | 2025-05-17 | 346 | 183d | 0d | 3,971,433.33 |
| 363 | 6.3.2.3.6 | Instalación de tuberías sanitarias Piso 6 | 4d | 2025-05-26 | 2025-05-30 | 347 | 172d | 0d | 3,971,433.33 |
| 364 | 6.3.2.3.7 | Instalación de tuberías sanitarias Piso 7 | 4d | 2025-06-09 | 2025-06-12 | 348 | 161d | 0d | 3,971,433.33 |
| 365 | 6.3.2.3.8 | Instalación de tuberías sanitarias Piso 8 | 4d | 2025-06-20 | 2025-06-26 | 349 | 150d | 0d | 3,971,433.33 |
| 366 | 6.3.2.3.9 | Instalación de tuberías sanitarias Piso 9 | 4d | 2025-07-05 | 2025-07-10 | 350 | 139d | 0d | 3,971,433.33 |
| 367 | 6.3.2.3.10 | Instalación de tuberías sanitarias Piso 10 | 4d | 2025-07-17 | 2025-07-22 | 351 | 124d | 0d | 3,971,433.33 |
| 368 | 6.3.3 | **Red contra incendios** | 30d | 2025-07-15 | 2025-08-19 |  | 76d |  | 4,690,000 |
| 369 | 6.3.3.1 | Instalación de columna red contra incendios | 15d | 2025-07-15 | 2025-07-31 | 340 | 76d | 0d | 1,172,500 |
| 370 | 6.3.3.2 | Instalaciòn de Gabinetes y valvulas Cortina | 5d | 2025-07-31 | 2025-08-06 | 369 | 114d | 0d | 1,172,500 |
| 371 | 6.3.3.3 | Instalaciòn siamesa | 2d | 2025-08-06 | 2025-08-08 | 370 | 114d | 0d | 1,172,500 |
| 372 | 6.3.3.4 | Instalación de equipos de presión | 8d | 2025-08-09 | 2025-08-19 | 371 | 114d |  | 1,172,500 |
| 373 | 6.3.4 | **Red de gas** | 53d | 2025-07-31 | 2025-10-01 |  | 76d |  | 28,550,000.05 |
| 374 | 6.3.4.1 | Prolongaciòn de Verticales | 8d | 2025-07-31 | 2025-08-11 | 369 | 76d | 0d | 2,196,153.85 |
| 375 | 6.3.4.2 | **Prolongación de tuberías en pisos** | 30d | 2025-08-11 | 2025-09-15 |  | 76d |  | 21,961,538.5 |
| 376 | 6.3.4.2.1 | Prolongación de tuberías de gas en Piso 1 | 3d | 2025-08-11 | 2025-08-13 | 374 | 76d | 0d | 2,196,153.85 |
| 377 | 6.3.4.2.2 | Prolongación de tuberías de gas en Piso 2 | 3d | 2025-08-14 | 2025-08-19 | 376 | 76d | 0d | 2,196,153.85 |
| 378 | 6.3.4.2.3 | Prolongación de tuberías de gas en Piso 3 | 3d | 2025-08-19 | 2025-08-21 | 377 | 76d | 0d | 2,196,153.85 |
| 379 | 6.3.4.2.4 | Prolongación de tuberías de gas en Piso 4 | 3d | 2025-08-21 | 2025-08-25 | 378 | 76d | 0d | 2,196,153.85 |
| 380 | 6.3.4.2.5 | Prolongación de tuberías de gas en Piso 5 | 3d | 2025-08-25 | 2025-08-28 | 379 | 76d | 0d | 2,196,153.85 |
| 381 | 6.3.4.2.6 | Prolongación de tuberías de gas en Piso 6 | 3d | 2025-08-28 | 2025-09-01 | 380 | 76d | 0d | 2,196,153.85 |
| 382 | 6.3.4.2.7 | Prolongación de tuberías de gas en Piso 7 | 3d | 2025-09-01 | 2025-09-04 | 381 | 76d | 0d | 2,196,153.85 |
| 383 | 6.3.4.2.8 | Prolongación de tuberías de gas en Piso 8 | 3d | 2025-09-04 | 2025-09-08 | 382 | 76d | 0d | 2,196,153.85 |
| 384 | 6.3.4.2.9 | Prolongación de tuberías de gas en Piso 9 | 3d | 2025-09-08 | 2025-09-11 | 383 | 76d | 0d | 2,196,153.85 |
| 385 | 6.3.4.2.10 | Prolongación de tuberías de gas en Piso 10 | 3d | 2025-09-11 | 2025-09-15 | 384 | 76d | 0d | 2,196,153.85 |
| 386 | 6.3.4.3 | Centro de medición segunda etapa | 10d | 2025-09-15 | 2025-09-25 | 385 | 76d | 0d | 2,196,153.85 |
| 387 | 6.3.4.4 | Reguladores primera etapa | 5d | 2025-09-25 | 2025-10-01 | 386 | 76d |  | 2,196,153.85 |

| ID | WBS | Task | Duration | Start | Finish | Predecessors | Total slack | Free slack | Cost |
| --- | --- | --- | --- | --- | --- | --- | --- | --- | --- |
| 388 | 6.3.5 | **Instalaciones eléctricas** | 245d | 2025-01-20 | 2025-11-04 |  | 48d |  | 249,999,999.8 |
| 389 | 6.3.5.1 | Malla a tierra | 3d | 2025-01-20 | 2025-01-23 | 69SF | 290d |  | 12,500,000 |
| 390 | 6.3.5.2 | Prolongación de ducteria vertical | 136d | 2025-03-04 | 2025-08-13 | 251SS | 97d | 0d | 12,500,000 |
| 391 | 6.3.5.3 | **Prolongación de tuberías en pisos** | 113d | 2025-04-04 | 2025-08-19 |  | 104d |  | 24,999,999.97 |
| 392 | 6.3.5.3.1 | Prolongación de tuberías eléctricas en piso 1 | 7d | 2025-04-04 | 2025-04-12 | 273 | 210d | 0d | 2,272,727.27 |
| 393 | 6.3.5.3.2 | Prolongación de tuberías eléctricas en piso 2 | 7d | 2025-04-19 | 2025-04-28 | 274 | 199d | 0d | 2,272,727.27 |
| 394 | 6.3.5.3.3 | Prolongación de tuberías eléctricas en piso 3 | 7d | 2025-05-03 | 2025-05-12 | 275 | 188d | 0d | 2,272,727.27 |
| 395 | 6.3.5.3.4 | Prolongación de tuberías eléctricas en piso 4 | 7d | 2025-05-15 | 2025-05-23 | 276 | 177d | 0d | 2,272,727.27 |
| 396 | 6.3.5.3.5 | Prolongación de tuberías eléctricas en piso 5 | 7d | 2025-05-28 | 2025-06-05 | 277 | 166d | 0d | 2,272,727.27 |
| 397 | 6.3.5.3.6 | Prolongación de tuberías eléctricas en piso 6 | 7d | 2025-06-11 | 2025-06-18 | 278 | 155d | 0d | 2,272,727.27 |
| 398 | 6.3.5.3.7 | Prolongación de tuberías eléctricas en piso 7 | 7d | 2025-06-24 | 2025-07-03 | 279 | 144d | 0d | 2,272,727.27 |
| 399 | 6.3.5.3.8 | Prolongación de tuberías eléctricas en piso 8 | 7d | 2025-07-08 | 2025-07-15 | 280 | 133d | 0d | 2,272,727.27 |
| 400 | 6.3.5.3.9 | Prolongación de tuberías eléctricas en piso 9 | 7d | 2025-07-21 | 2025-07-28 | 281 | 122d | 0d | 2,272,727.27 |
| 401 | 6.3.5.3.10 | Prolongación de tuberías eléctricas en piso 10 | 7d | 2025-08-01 | 2025-08-11 | 282 | 104d | 0d | 2,272,727.27 |
| 402 | 6.3.5.3.11 | Prolongación de tuberías eléctricas en Terraza | 7d | 2025-08-11 | 2025-08-19 | 283 | 48d | 0d | 2,272,727.27 |
| 403 | 6.3.5.4 | **Alambrada pisos** | 121d | 2025-04-12 | 2025-09-05 |  | 95d |  | 24,999,999.96 |
| 404 | 6.3.5.4.1 | Alambrada Piso 1 | 5d | 2025-04-12 | 2025-04-21 | 392 | 211d | 0d | 2,083,333.33 |
| 405 | 6.3.5.4.2 | Alambrada Piso 2 | 5d | 2025-04-28 | 2025-05-05 | 393 | 200d | 0d | 2,083,333.33 |
| 406 | 6.3.5.4.3 | Alambrada Piso 3 | 5d | 2025-05-12 | 2025-05-16 | 394 | 189d | 0d | 2,083,333.33 |
| 407 | 6.3.5.4.4 | Alambrada Piso 4 | 5d | 2025-05-23 | 2025-05-29 | 395 | 178d | 0d | 2,083,333.33 |
| 408 | 6.3.5.4.5 | Alambrada Piso 5 | 5d | 2025-06-06 | 2025-06-11 | 396 | 167d | 0d | 2,083,333.33 |
| 409 | 6.3.5.4.6 | Alambrada Piso 6 | 5d | 2025-06-18 | 2025-06-25 | 397 | 156d | 0d | 2,083,333.33 |
| 410 | 6.3.5.4.7 | Alambrada Piso 7 | 5d | 2025-07-03 | 2025-07-09 | 398 | 145d | 0d | 2,083,333.33 |
| 411 | 6.3.5.4.8 | Alambrada Piso 8 | 5d | 2025-07-16 | 2025-07-21 | 399 | 134d | 0d | 2,083,333.33 |
| 412 | 6.3.5.4.9 | Alambrada Piso 9 | 5d | 2025-07-28 | 2025-08-02 | 400 | 123d | 0d | 2,083,333.33 |
| 413 | 6.3.5.4.10 | Alambrada Piso 10 | 5d | 2025-08-11 | 2025-08-15 | 401 | 112d | 0d | 2,083,333.33 |
| 414 | 6.3.5.4.11 | Alambrada Terraza | 5d | 2025-08-20 | 2025-08-25 | 402 | 48d | 0d | 2,083,333.33 |
| 415 | 6.3.5.4.12 | Alambrada Zonas Comunes | 10d | 2025-08-25 | 2025-09-05 | 414 | 48d | 0d | 2,083,333.33 |

| ID | WBS | Task | Duration | Start | Finish | Predecessors | Total slack | Free slack | Cost |
| --- | --- | --- | --- | --- | --- | --- | --- | --- | --- |
| 416 | 6.3.5.5 | **Aparateada pisos** | 123d | 2025-04-21 | 2025-09-12 |  | 91d |  | 24,999,999.96 |
| 417 | 6.3.5.5.1 | Aparateada piso 1 | 3d | 2025-04-21 | 2025-04-24 | 404 | 211d | 0d | 2,083,333.33 |
| 418 | 6.3.5.5.2 | Aparateada piso 2 | 3d | 2025-05-05 | 2025-05-07 | 405 | 200d | 0d | 2,083,333.33 |
| 419 | 6.3.5.5.3 | Aparateada piso 3 | 3d | 2025-05-16 | 2025-05-20 | 406 | 189d | 0d | 2,083,333.33 |
| 420 | 6.3.5.5.4 | Aparateada piso 4 | 3d | 2025-05-29 | 2025-06-03 | 407 | 178d | 0d | 2,083,333.33 |
| 421 | 6.3.5.5.5 | Aparateada piso 5 | 3d | 2025-06-11 | 2025-06-14 | 408 | 167d | 0d | 2,083,333.33 |
| 422 | 6.3.5.5.6 | Aparateada piso 6 | 3d | 2025-06-25 | 2025-06-28 | 409 | 156d | 0d | 2,083,333.33 |
| 423 | 6.3.5.5.7 | Aparateada piso 7 | 3d | 2025-07-09 | 2025-07-11 | 410 | 145d | 0d | 2,083,333.33 |
| 424 | 6.3.5.5.8 | Aparateada piso 8 | 3d | 2025-07-21 | 2025-07-24 | 411 | 134d | 0d | 2,083,333.33 |
| 425 | 6.3.5.5.9 | Aparateada piso 9 | 3d | 2025-08-02 | 2025-08-06 | 412 | 123d | 0d | 2,083,333.33 |
| 426 | 6.3.5.5.10 | Aparateada piso 10 | 3d | 2025-08-15 | 2025-08-20 | 413 | 112d | 0d | 2,083,333.33 |
| 427 | 6.3.5.5.11 | Aparateada Terraza | 3d | 2025-08-25 | 2025-08-28 | 414 | 105d | 0d | 2,083,333.33 |
| 428 | 6.3.5.5.12 | Aparateada Zonas Comunes | 7d | 2025-09-05 | 2025-09-12 | 415 | 48d | 0d | 2,083,333.33 |
| 429 | 6.3.5.6 | **Instalación de tableros y breakers** | 122d | 2025-04-24 | 2025-09-16 |  | 90d |  | 24,999,999.96 |
| 430 | 6.3.5.6.1 | Instalación de tableros y breakers piso 1 | 1d | 2025-04-24 | 2025-04-25 | 417 | 211d |  | 2,083,333.33 |
| 431 | 6.3.5.6.2 | Instalación de tableros y breakers piso 2 | 1d | 2025-05-08 | 2025-05-08 | 418 | 200d |  | 2,083,333.33 |
| 432 | 6.3.5.6.3 | Instalación de tableros y breakers piso 3 | 1d | 2025-05-20 | 2025-05-21 | 419 | 189d |  | 2,083,333.33 |
| 433 | 6.3.5.6.4 | Instalación de tableros y breakers piso 4 | 1d | 2025-06-03 | 2025-06-04 | 420 | 178d |  | 2,083,333.33 |
| 434 | 6.3.5.6.5 | Instalación de tableros y breakers piso 5 | 1d | 2025-06-16 | 2025-06-16 | 421 | 167d |  | 2,083,333.33 |
| 435 | 6.3.5.6.6 | Instalación de tableros y breakers piso 6 | 1d | 2025-06-28 | 2025-07-01 | 422 | 156d |  | 2,083,333.33 |
| 436 | 6.3.5.6.7 | Instalación de tableros y breakers piso 7 | 1d | 2025-07-11 | 2025-07-14 | 423 | 145d |  | 2,083,333.33 |
| 437 | 6.3.5.6.8 | Instalación de tableros y breakers piso 8 | 1d | 2025-07-24 | 2025-07-25 | 424 | 134d |  | 2,083,333.33 |
| 438 | 6.3.5.6.9 | Instalación de tableros y breakers piso 9 | 1d | 2025-08-06 | 2025-08-08 | 425 | 123d |  | 2,083,333.33 |
| 439 | 6.3.5.6.10 | Instalación de tableros y breakers piso 10 | 1d | 2025-08-20 | 2025-08-21 | 426 | 112d |  | 2,083,333.33 |
| 440 | 6.3.5.6.11 | Instalación de tableros y breakers Terraza | 1d | 2025-08-28 | 2025-08-29 | 427 | 105d |  | 2,083,333.33 |
| 441 | 6.3.5.6.12 | Instalación de tableros y breakers Zonas Comunes | 2d | 2025-09-12 | 2025-09-16 | 428 | 48d | 0d | 2,083,333.33 |

| ID | WBS | Task | Duration | Start | Finish | Predecessors | Total slack | Free slack | Cost |
| --- | --- | --- | --- | --- | --- | --- | --- | --- | --- |
| 442 | 6.3.5.7 | **Instalación de lámparas y sensores** | 5d | 2025-09-05 | 2025-09-11 |  | 94d |  | 24,999,999.99 |
| 443 | 6.3.5.7.1 | Instalación de lamparas de emergencia | 5d | 2025-09-05 | 2025-09-11 | 415 | 94d |  | 8,333,333.33 |
| 444 | 6.3.5.7.2 | Instalación de lamparas hológenas | 5d | 2025-09-05 | 2025-09-11 | 415 | 94d |  | 8,333,333.33 |
| 445 | 6.3.5.7.3 | Instalación de sensores de movimiento | 5d | 2025-09-05 | 2025-09-11 | 415 | 94d |  | 8,333,333.33 |
| 446 | 6.3.5.8 | **Acometidas** | 123d | 2025-04-12 | 2025-09-08 |  | 97d |  | 25,000,000 |
| 447 | 6.3.5.8.1 | Acometida 110V foso de ascensor | 2d | 2025-04-12 | 2025-04-15 | 392 | 216d | 0d | 5,000,000 |
| 448 | 6.3.5.8.2 | Acometida trifásica foso de ascensor | 2d | 2025-04-15 | 2025-04-19 | 447 | 216d |  | 5,000,000 |
| 449 | 6.3.5.8.3 | Prolongación parciales cuarto de bombas,cuarto de maquinas, duplicadores y servicios comunes | 5d | 2025-08-13 | 2025-08-19 | 390 | 114d |  | 5,000,000 |
| 450 | 6.3.5.8.4 | Alambrada acometidas parciales a apartamentos (verticales) | 20d | 2025-08-13 | 2025-09-05 | 390 | 97d | 0d | 5,000,000 |
| 451 | 6.3.5.8.5 | Alambrada de parciales a medidores | 2d | 2025-09-05 | 2025-09-08 | 450 | 97d |  | 5,000,000 |
| 452 | 6.3.5.9 | **Iluminación cuartos técnicos** | 111d | 2025-04-12 | 2025-08-25 |  | 109d |  | 25,000,000 |
| 453 | 6.3.5.9.1 | Iluminación cuarto de máquinas | 5d | 2025-08-20 | 2025-08-25 | 402 | 109d |  | 12,500,000 |
| 454 | 6.3.5.9.2 | Iluminación foso de ascensor | 5d | 2025-04-12 | 2025-04-21 | 392 | 215d |  | 12,500,000 |
| 455 | 6.3.5.10 | **Armarios** | 42d | 2025-09-16 | 2025-11-04 |  | 48d |  | 25,000,000 |
| 456 | 6.3.5.10.1 | Instalación y conexión de armarios electricos | 20d | 2025-09-16 | 2025-10-08 | 441 | 48d | 0d | 6,250,000 |
| 457 | 6.3.5.10.2 | Instalación y conexión de TGA | 10d | 2025-10-08 | 2025-10-20 | 456 | 48d | 0d | 6,250,000 |
| 458 | 6.3.5.10.3 | Instalación de Celdas SF6 y transformador | 10d | 2025-10-21 | 2025-10-31 | 457 | 48d | 0d | 6,250,000 |
| 459 | 6.3.5.10.4 | Instalación tablero servicios comunes | 2d | 2025-10-31 | 2025-11-04 | 458 | 48d |  | 6,250,000 |
| 460 | 6.3.5.11 | **Serie3** | 22d | 2025-10-08 | 2025-11-04 |  | 48d |  | 24,999,999.96 |
| 461 | 6.3.5.11.1 | Prolongación red CS 276-I a celda SF6 | 5d | 2025-10-10 | 2025-10-16 | 741 | 52d | 0d | 2,083,333.33 |
| 462 | 6.3.5.11.2 | Prolongación tuberia transformador y celda | 3d | 2025-10-16 | 2025-10-20 | 461 | 52d | 0d | 2,083,333.33 |
| 463 | 6.3.5.11.3 | Prolongación iluminación sub-estación | 3d | 2025-10-21 | 2025-10-23 | 462 | 52d | 0d | 2,083,333.33 |
| 464 | 6.3.5.11.4 | Prolongación tuberia tranformador a TGA-armarios | 3d | 2025-10-23 | 2025-10-27 | 463 | 52d | 0d | 2,083,333.33 |
| 465 | 6.3.5.11.5 | Alambrada tuberia y carcamos transformador y celda | 2d | 2025-10-21 | 2025-10-22 | 462 | 58d |  | 2,083,333.33 |
| 466 | 6.3.5.11.6 | Alambrada iluminación sub-estación | 2d | 2025-10-23 | 2025-10-25 | 463 | 55d |  | 2,083,333.33 |
| 467 | 6.3.5.11.7 | Alambrada de celda a TGA | 2d | 2025-10-27 | 2025-10-29 | 464 | 52d |  | 2,083,333.33 |
| 468 | 6.3.5.11.8 | Alambrada tuberia tranformador a TGA-ARMARIOS | 2d | 2025-10-31 | 2025-11-04 | 458 | 48d |  | 2,083,333.33 |
| 469 | 6.3.5.11.9 | Prolongación tuberia CS 276-I a CS 276-II | 3d | 2025-10-08 | 2025-10-10 | 757 | 59d | 0d | 2,083,333.33 |
| 470 | 6.3.5.11.10 | Prolongación tuberia CS 276-II a CS 276-Existente | 3d | 2025-10-10 | 2025-10-15 | 469 | 59d | 0d | 2,083,333.33 |
| 471 | 6.3.5.11.11 | Alambrada red celda SF6 a CS 276 E | 3d | 2025-10-16 | 2025-10-20 | 470 | 59d | 0d | 2,083,333.33 |
| 472 | 6.3.5.11.12 | Afloramiento del punto de conexión | 2d | 2025-10-20 | 2025-10-21 | 471 | 59d |  | 2,083,333.33 |

| ID | WBS | Task | Duration | Start | Finish | Predecessors | Total slack | Free slack | Cost |
| --- | --- | --- | --- | --- | --- | --- | --- | --- | --- |
| 473 | 6.3.6 | **Telecomunicaciones y citofonía** | 116d | 2025-04-12 | 2025-08-30 |  | 104d |  | 50,000,000.2 |
| 474 | 6.3.6.1 | **Telecomunicaciones y citofonía Piso 1** | 10d | 2025-04-12 | 2025-04-26 |  | 210d |  | 4,545,454.56 |
| 475 | 6.3.6.1.1 | Prolongación de tuberia de telecomunicaciones Piso 1 | 7d | 2025-04-12 | 2025-04-23 | 392 | 210d | 0d | 1,515,151.52 |
| 476 | 6.3.6.1.2 | Instalación de cajas PAU Piso 1 | 2d | 2025-04-23 | 2025-04-25 | 475 | 210d | 0d | 1,515,151.52 |
| 477 | 6.3.6.1.3 | Instalación de gabinete de piso 1 | 1d | 2025-04-25 | 2025-04-26 | 476 | 210d |  | 1,515,151.52 |
| 478 | 6.3.6.2 | **Telecomunicaciones y citofonía Piso 2** | 10d | 2025-04-28 | 2025-05-09 |  | 199d |  | 4,545,454.56 |
| 479 | 6.3.6.2.1 | Prolongación de tuberia de telecomunicaciones Piso 2 | 7d | 2025-04-28 | 2025-05-07 | 393 | 199d | 0d | 1,515,151.52 |
| 480 | 6.3.6.2.2 | Instalación de cajas PAU Piso 2 | 2d | 2025-05-07 | 2025-05-08 | 479 | 199d | 0d | 1,515,151.52 |
| 481 | 6.3.6.2.3 | Instalación de gabinete de piso 2 | 1d | 2025-05-08 | 2025-05-09 | 480 | 199d |  | 1,515,151.52 |
| 482 | 6.3.6.3 | **Telecomunicaciones y citofonía Piso 3** | 10d | 2025-05-12 | 2025-05-22 |  | 188d |  | 4,545,454.56 |
| 483 | 6.3.6.3.1 | Prolongación de tuberia de telecomunicaciones Piso 3 | 7d | 2025-05-12 | 2025-05-19 | 394 | 188d | 0d | 1,515,151.52 |
| 484 | 6.3.6.3.2 | Instalación de cajas PAU Piso 3 | 2d | 2025-05-19 | 2025-05-21 | 483 | 188d | 0d | 1,515,151.52 |
| 485 | 6.3.6.3.3 | Instalación de gabinete de piso 3 | 1d | 2025-05-21 | 2025-05-22 | 484 | 188d |  | 1,515,151.52 |
| 486 | 6.3.6.4 | **Telecomunicaciones y citofonía Piso 4** | 10d | 2025-05-23 | 2025-06-05 |  | 177d |  | 4,545,454.56 |
| 487 | 6.3.6.4.1 | Prolongación de tuberia de telecomunicaciones Piso 4 | 7d | 2025-05-23 | 2025-05-30 | 395 | 177d | 0d | 1,515,151.52 |
| 488 | 6.3.6.4.2 | Instalación de cajas PAU Piso 4 | 2d | 2025-05-31 | 2025-06-04 | 487 | 177d | 0d | 1,515,151.52 |
| 489 | 6.3.6.4.3 | Instalación de gabinete de piso 4 | 1d | 2025-06-04 | 2025-06-05 | 488 | 177d |  | 1,515,151.52 |
| 490 | 6.3.6.5 | **Telecomunicaciones y citofonía Piso 5** | 10d | 2025-06-06 | 2025-06-17 |  | 166d |  | 4,545,454.56 |
| 491 | 6.3.6.5.1 | Prolongación de tuberia de telecomunicaciones Piso 5 | 7d | 2025-06-06 | 2025-06-13 | 396 | 166d | 0d | 1,515,151.52 |
| 492 | 6.3.6.5.2 | Instalación de cajas PAU Piso 5 | 2d | 2025-06-13 | 2025-06-16 | 491 | 166d | 0d | 1,515,151.52 |
| 493 | 6.3.6.5.3 | Instalación de gabinete de piso 5 | 1d | 2025-06-16 | 2025-06-17 | 492 | 166d |  | 1,515,151.52 |
| 494 | 6.3.6.6 | **Telecomunicaciones y citofonía Piso 6** | 10d | 2025-06-18 | 2025-07-02 |  | 155d |  | 4,545,454.56 |
| 495 | 6.3.6.6.1 | Prolongación de tuberia de telecomunicaciones Piso 6 | 7d | 2025-06-18 | 2025-06-27 | 397 | 155d | 0d | 1,515,151.52 |
| 496 | 6.3.6.6.2 | Instalación de cajas PAU Piso 6 | 2d | 2025-06-27 | 2025-07-01 | 495 | 155d | 0d | 1,515,151.52 |
| 497 | 6.3.6.6.3 | Instalación de gabinete de piso 6 | 1d | 2025-07-01 | 2025-07-02 | 496 | 155d |  | 1,515,151.52 |

| ID | WBS | Task | Duration | Start | Finish | Predecessors | Total slack | Free slack | Cost |
| --- | --- | --- | --- | --- | --- | --- | --- | --- | --- |
| 498 | 6.3.6.7 | **Telecomunicaciones y citofonía Piso 7** | 10d | 2025-07-03 | 2025-07-15 |  | 144d |  | 4,545,454.56 |
| 499 | 6.3.6.7.1 | Prolongación de tuberia de telecomunicaciones Piso 7 | 7d | 2025-07-03 | 2025-07-10 | 398 | 144d | 0d | 1,515,151.52 |
| 500 | 6.3.6.7.2 | Instalación de cajas PAU Piso 7 | 2d | 2025-07-11 | 2025-07-14 | 499 | 144d | 0d | 1,515,151.52 |
| 501 | 6.3.6.7.3 | Instalación de gabinete de piso 7 | 1d | 2025-07-14 | 2025-07-15 | 500 | 144d |  | 1,515,151.52 |
| 502 | 6.3.6.8 | **Telecomunicaciones y citofonía Piso 8** | 10d | 2025-07-16 | 2025-07-26 |  | 133d |  | 4,545,454.56 |
| 503 | 6.3.6.8.1 | Prolongación de tuberia de telecomunicaciones Piso 8 | 7d | 2025-07-16 | 2025-07-23 | 399 | 133d | 0d | 1,515,151.52 |
| 504 | 6.3.6.8.2 | Instalación de cajas PAU Piso 8 | 2d | 2025-07-23 | 2025-07-25 | 503 | 133d | 0d | 1,515,151.52 |
| 505 | 6.3.6.8.3 | Instalación de gabinete de piso 8 | 1d | 2025-07-25 | 2025-07-26 | 504 | 133d |  | 1,515,151.52 |
| 506 | 6.3.6.9 | **Telecomunicaciones y citofonía Piso 9** | 10d | 2025-07-28 | 2025-08-08 |  | 122d |  | 4,545,454.56 |
| 507 | 6.3.6.9.1 | Prolongación de tuberia de telecomunicaciones Piso 9 | 7d | 2025-07-28 | 2025-08-05 | 400 | 122d | 0d | 1,515,151.52 |
| 508 | 6.3.6.9.2 | Instalación de cajas PAU Piso 9 | 2d | 2025-08-05 | 2025-08-08 | 507 | 122d | 0d | 1,515,151.52 |
| 509 | 6.3.6.9.3 | Instalación de gabinete de piso 9 | 1d | 2025-08-08 | 2025-08-08 | 508 | 122d |  | 1,515,151.52 |
| 510 | 6.3.6.10 | **Telecomunicaciones y citofonía Piso 10** | 10d | 2025-08-11 | 2025-08-22 |  | 104d |  | 4,545,454.56 |
| 511 | 6.3.6.10.1 | Prolongación de tuberia de telecomunicaciones Piso 10 | 7d | 2025-08-11 | 2025-08-19 | 401 | 104d | 0d | 1,515,151.52 |
| 512 | 6.3.6.10.2 | Instalación de cajas PAU Piso 10 | 2d | 2025-08-20 | 2025-08-21 | 511 | 111d | 0d | 1,515,151.52 |
| 513 | 6.3.6.10.3 | Instalación de gabinete de piso 10 | 1d | 2025-08-21 | 2025-08-22 | 512 | 111d |  | 1,515,151.52 |
| 514 | 6.3.6.11 | **Cableado timbres y camaras (p1-p10)** | 10d | 2025-08-20 | 2025-08-30 |  | 104d |  | 4,545,454.6 |
| 515 | 6.3.6.11.1 | Cableado timbres y camaras piso 1 | 1d | 2025-08-20 | 2025-08-20 | 511 | 104d | 0d | 454,545.46 |
| 516 | 6.3.6.11.2 | Cableado timbres y camaras piso 2 | 1d | 2025-08-20 | 2025-08-21 | 515 | 104d | 0d | 454,545.46 |
| 517 | 6.3.6.11.3 | Cableado timbres y camaras piso 3 | 1d | 2025-08-21 | 2025-08-22 | 516 | 104d | 0d | 454,545.46 |
| 518 | 6.3.6.11.4 | Cableado timbres y camaras piso 4 | 1d | 2025-08-22 | 2025-08-23 | 517 | 104d | 0d | 454,545.46 |
| 519 | 6.3.6.11.5 | Cableado timbres y camaras piso 5 | 1d | 2025-08-25 | 2025-08-25 | 518 | 104d | 0d | 454,545.46 |
| 520 | 6.3.6.11.6 | Cableado timbres y camaras piso 6 | 1d | 2025-08-25 | 2025-08-26 | 519 | 104d | 0d | 454,545.46 |
| 521 | 6.3.6.11.7 | Cableado timbres y camaras piso 7 | 1d | 2025-08-26 | 2025-08-27 | 520 | 104d | 0d | 454,545.46 |
| 522 | 6.3.6.11.8 | Cableado timbres y camaras piso 8 | 1d | 2025-08-27 | 2025-08-28 | 521 | 104d | 0d | 454,545.46 |
| 523 | 6.3.6.11.9 | Cableado timbres y camaras piso 9 | 1d | 2025-08-28 | 2025-08-29 | 522 | 104d | 0d | 454,545.46 |
| 524 | 6.3.6.11.10 | Cableado timbres y camaras piso 10 | 1d | 2025-08-29 | 2025-08-30 | 523 | 104d |  | 454,545.46 |

| ID | WBS | Task | Duration | Start | Finish | Predecessors | Total slack | Free slack | Cost |
| --- | --- | --- | --- | --- | --- | --- | --- | --- | --- |
| 525 | 6.4 | **Obra blanca** | 156d | 2025-03-26 | 2025-09-26 |  | 80d |  | 163,262,373.75 |
| 526 | 6.4.1 | **Cielo rasos** | 112d | 2025-03-26 | 2025-08-06 |  | 124d |  | 11,387,640 |
| 527 | 6.4.1.1 | **Estructurada de cielo raso** | 107d | 2025-03-26 | 2025-07-31 |  | 124d |  | 2,277,528 |
| 528 | 6.4.1.1.1 | Estructurada de cielo raso Piso 1 | 4d | 2025-03-26 | 2025-03-31 | 358 | 227d | 0d | 207,048 |
| 529 | 6.4.1.1.2 | Estructurada de cielo raso Piso 2 | 4d | 2025-04-07 | 2025-04-11 | 359 | 216d | 0d | 207,048 |
| 530 | 6.4.1.1.3 | Estructurada de cielo raso Piso 3 | 4d | 2025-04-22 | 2025-04-26 | 360 | 205d | 0d | 207,048 |
| 531 | 6.4.1.1.4 | Estructurada de cielo raso Piso 4 | 4d | 2025-05-06 | 2025-05-09 | 361 | 194d | 0d | 207,048 |
| 532 | 6.4.1.1.5 | Estructurada de cielo raso Piso 5 | 4d | 2025-05-17 | 2025-05-22 | 362 | 183d | 0d | 207,048 |
| 533 | 6.4.1.1.6 | Estructurada de cielo raso Piso 6 | 4d | 2025-05-30 | 2025-06-05 | 363 | 172d | 0d | 207,048 |
| 534 | 6.4.1.1.7 | Estructurada de cielo raso Piso 7 | 4d | 2025-06-12 | 2025-06-17 | 364 | 161d | 0d | 207,048 |
| 535 | 6.4.1.1.8 | Estructurada de cielo raso Piso 8 | 4d | 2025-06-26 | 2025-07-02 | 365 | 150d | 0d | 207,048 |
| 536 | 6.4.1.1.9 | Estructurada de cielo raso Piso 9 | 4d | 2025-07-10 | 2025-07-15 | 366 | 139d | 0d | 207,048 |
| 537 | 6.4.1.1.10 | Estructurada de cielo raso Piso 10 | 4d | 2025-07-22 | 2025-07-26 | 367 | 124d | 0d | 207,048 |
| 538 | 6.4.1.1.11 | Estructurada de cielo raso terraza | 4d | 2025-07-26 | 2025-07-31 | 537 | 124d | 0d | 207,048 |
| 539 | 6.4.1.2 | **Tapada de cielo raso** | 106d | 2025-03-31 | 2025-08-04 |  | 124d |  | 7,971,348 |
| 540 | 6.4.1.2.1 | Tapada de cielo raso piso 1 | 3d | 2025-03-31 | 2025-04-02 | 528 | 227d | 0d | 724,668 |
| 541 | 6.4.1.2.2 | Tapada de cielo raso piso 2 | 3d | 2025-04-11 | 2025-04-15 | 529 | 216d | 0d | 724,668 |
| 542 | 6.4.1.2.3 | Tapada de cielo raso piso 3 | 3d | 2025-04-26 | 2025-04-30 | 530 | 205d | 0d | 724,668 |
| 543 | 6.4.1.2.4 | Tapada de cielo raso piso 4 | 3d | 2025-05-09 | 2025-05-13 | 531 | 194d | 0d | 724,668 |
| 544 | 6.4.1.2.5 | Tapada de cielo raso piso 5 | 3d | 2025-05-22 | 2025-05-26 | 532 | 183d | 0d | 724,668 |
| 545 | 6.4.1.2.6 | Tapada de cielo raso piso 6 | 3d | 2025-06-05 | 2025-06-09 | 533 | 172d | 0d | 724,668 |
| 546 | 6.4.1.2.7 | Tapada de cielo raso piso 7 | 3d | 2025-06-17 | 2025-06-20 | 534 | 161d | 0d | 724,668 |
| 547 | 6.4.1.2.8 | Tapada de cielo raso piso 8 | 3d | 2025-07-02 | 2025-07-05 | 535 | 150d | 0d | 724,668 |
| 548 | 6.4.1.2.9 | Tapada de cielo raso piso 9 | 3d | 2025-07-15 | 2025-07-17 | 536 | 139d | 0d | 724,668 |
| 549 | 6.4.1.2.10 | Tapada de cielo raso piso 10 | 3d | 2025-07-26 | 2025-07-30 | 537 | 128d | 0d | 724,668 |
| 550 | 6.4.1.2.11 | Tapada de cielo raso terraza | 3d | 2025-07-31 | 2025-08-04 | 538 | 124d | 0d | 724,668 |

| ID | WBS | Task | Duration | Start | Finish | Predecessors | Total slack | Free slack | Cost |
| --- | --- | --- | --- | --- | --- | --- | --- | --- | --- |
| 551 | 6.4.1.3 | **Pintura de cielo raso** | 105d | 2025-04-02 | 2025-08-06 |  | 124d |  | 1,138,764 |
| 552 | 6.4.1.3.1 | Pintura de cielo raso piso 1 | 2d | 2025-04-02 | 2025-04-04 | 540 | 227d |  | 103,524 |
| 553 | 6.4.1.3.2 | Pintura de cielo raso piso 2 | 2d | 2025-04-15 | 2025-04-19 | 541 | 216d |  | 103,524 |
| 554 | 6.4.1.3.3 | Pintura de cielo raso piso 3 | 2d | 2025-04-30 | 2025-05-02 | 542 | 205d |  | 103,524 |
| 555 | 6.4.1.3.4 | Pintura de cielo raso piso 4 | 2d | 2025-05-13 | 2025-05-15 | 543 | 194d |  | 103,524 |
| 556 | 6.4.1.3.5 | Pintura de cielo raso piso 5 | 2d | 2025-05-26 | 2025-05-28 | 544 | 183d |  | 103,524 |
| 557 | 6.4.1.3.6 | Pintura de cielo raso piso 6 | 2d | 2025-06-09 | 2025-06-10 | 545 | 172d |  | 103,524 |
| 558 | 6.4.1.3.7 | Pintura de cielo raso piso 7 | 2d | 2025-06-20 | 2025-06-24 | 546 | 161d |  | 103,524 |
| 559 | 6.4.1.3.8 | Pintura de cielo raso piso 8 | 2d | 2025-07-05 | 2025-07-08 | 547 | 150d |  | 103,524 |
| 560 | 6.4.1.3.9 | Pintura de cielo raso piso 9 | 2d | 2025-07-17 | 2025-07-19 | 548 | 139d |  | 103,524 |
| 561 | 6.4.1.3.10 | Pintura de cielo raso piso 10 | 2d | 2025-07-30 | 2025-08-01 | 549 | 128d |  | 103,524 |
| 562 | 6.4.1.3.11 | Pintura de cielo raso terraza | 2d | 2025-08-04 | 2025-08-06 | 550 | 124d |  | 103,524 |
| 563 | 6.4.2 | **Enchape** | 111d | 2025-05-19 | 2025-09-26 |  | 80d |  | 104,873,389.09 |
| 564 | 6.4.2.1 | **Enchape sobre piso apartamentos** | 107d | 2025-05-19 | 2025-09-22 |  | 82d |  | 26,292,248.1 |
| 565 | 6.4.2.1.1 | Enchape piso local | 4d | 2025-05-19 | 2025-05-23 | 316FS+28d | 143d | 0d | 2,629,224.81 |
| 566 | 6.4.2.1.2 | Enchape sobre piso apartamentos piso 2 | 8d | 2025-05-31 | 2025-06-10 | 317FS+28d | 170d | 0d | 2,629,224.81 |
| 567 | 6.4.2.1.3 | Enchape sobre piso apartamentos piso 3 | 8d | 2025-06-13 | 2025-06-24 | 318FS+28d | 159d | 0d | 2,629,224.81 |
| 568 | 6.4.2.1.4 | Enchape sobre piso apartamentos piso 4 | 8d | 2025-06-27 | 2025-07-08 | 319FS+28d | 148d | 0d | 2,629,224.81 |
| 569 | 6.4.2.1.5 | Enchape sobre piso apartamentos piso 5 | 8d | 2025-07-11 | 2025-07-19 | 320FS+28d | 137d | 0d | 2,629,224.81 |
| 570 | 6.4.2.1.6 | Enchape sobre piso apartamentos piso 6 | 8d | 2025-07-23 | 2025-08-01 | 321FS+28d | 126d | 0d | 2,629,224.81 |
| 571 | 6.4.2.1.7 | Enchape sobre piso apartamentos piso 7 | 8d | 2025-08-05 | 2025-08-14 | 322FS+28d | 115d | 0d | 2,629,224.81 |
| 572 | 6.4.2.1.8 | Enchape sobre piso apartamentos piso 8 | 8d | 2025-08-20 | 2025-08-28 | 323FS+28d | 104d | 0d | 2,629,224.81 |
| 573 | 6.4.2.1.9 | Enchape sobre piso apartamentos piso 9 | 8d | 2025-09-01 | 2025-09-10 | 324FS+28d | 93d | 0d | 2,629,224.81 |
| 574 | 6.4.2.1.10 | Enchape sobre piso apartamentos piso 10 | 8d | 2025-09-12 | 2025-09-22 | 325FS+28d | 50d | 0d | 2,629,224.81 |

| ID | WBS | Task | Duration | Start | Finish | Predecessors | Total slack | Free slack | Cost |
| --- | --- | --- | --- | --- | --- | --- | --- | --- | --- |
| 575 | 6.4.2.2 | **Guardaescoba apartamentos** | 105d | 2025-05-23 | 2025-09-24 |  | 82d |  | 5,258,449.6 |
| 576 | 6.4.2.2.1 | Guardaescoba local | 1d | 2025-05-23 | 2025-05-24 | 565 | 186d |  | 525,844.96 |
| 577 | 6.4.2.2.2 | Guardaescoba apartamentos piso 2 | 2d | 2025-06-11 | 2025-06-12 | 566 | 170d |  | 525,844.96 |
| 578 | 6.4.2.2.3 | Guardaescoba apartamentos piso 3 | 2d | 2025-06-24 | 2025-06-26 | 567 | 159d |  | 525,844.96 |
| 579 | 6.4.2.2.4 | Guardaescoba apartamentos piso 4 | 2d | 2025-07-08 | 2025-07-10 | 568 | 148d |  | 525,844.96 |
| 580 | 6.4.2.2.5 | Guardaescoba apartamentos piso 5 | 2d | 2025-07-21 | 2025-07-22 | 569 | 137d |  | 525,844.96 |
| 581 | 6.4.2.2.6 | Guardaescoba apartamentos piso 6 | 2d | 2025-08-01 | 2025-08-04 | 570 | 126d |  | 525,844.96 |
| 582 | 6.4.2.2.7 | Guardaescoba apartamentos piso 7 | 2d | 2025-08-14 | 2025-08-19 | 571 | 115d |  | 525,844.96 |
| 583 | 6.4.2.2.8 | Guardaescoba apartamentos piso 8 | 2d | 2025-08-28 | 2025-08-30 | 572 | 104d |  | 525,844.96 |
| 584 | 6.4.2.2.9 | Guardaescoba apartamentos piso 9 | 2d | 2025-09-10 | 2025-09-11 | 573 | 93d |  | 525,844.96 |
| 585 | 6.4.2.2.10 | Guardaescoba apartamentos piso 10 | 2d | 2025-09-22 | 2025-09-24 | 574 | 82d |  | 525,844.96 |
| 586 | 6.4.2.3 | **Enchape sobre piso baños** | 101d | 2025-05-19 | 2025-09-16 |  | 86d |  | 6,150,000 |
| 587 | 6.4.2.3.1 | Enchape sobre piso baños piso 1 | 2d | 2025-05-19 | 2025-05-21 | 565SS | 185d | 0d | 615,000 |
| 588 | 6.4.2.3.2 | Enchape sobre piso baños piso 2 | 2d | 2025-05-31 | 2025-06-04 | 566SS | 172d | 0d | 615,000 |
| 589 | 6.4.2.3.3 | Enchape sobre piso baños piso 3 | 2d | 2025-06-13 | 2025-06-16 | 567SS | 161d | 0d | 615,000 |
| 590 | 6.4.2.3.4 | Enchape sobre piso baños piso 4 | 2d | 2025-06-27 | 2025-07-01 | 568SS | 150d | 0d | 615,000 |
| 591 | 6.4.2.3.5 | Enchape sobre piso baños piso 5 | 2d | 2025-07-11 | 2025-07-14 | 569SS | 139d | 0d | 615,000 |
| 592 | 6.4.2.3.6 | Enchape sobre piso baños piso 6 | 2d | 2025-07-23 | 2025-07-25 | 570SS | 128d | 0d | 615,000 |
| 593 | 6.4.2.3.7 | Enchape sobre piso baños piso 7 | 2d | 2025-08-05 | 2025-08-08 | 571SS | 117d | 0d | 615,000 |
| 594 | 6.4.2.3.8 | Enchape sobre piso baños piso 8 | 2d | 2025-08-20 | 2025-08-21 | 572SS | 106d | 0d | 615,000 |
| 595 | 6.4.2.3.9 | Enchape sobre piso baños piso 9 | 2d | 2025-09-01 | 2025-09-03 | 573SS | 95d | 0d | 615,000 |
| 596 | 6.4.2.3.10 | Enchape sobre piso baños piso 10 | 2d | 2025-09-12 | 2025-09-16 | 574SS | 50d | 0d | 615,000 |
| 597 | 6.4.2.4 | **Enchape sobre muro baños** | 103d | 2025-05-21 | 2025-09-19 |  | 86d |  | 26,292,248.1 |
| 598 | 6.4.2.4.1 | Enchape sobre muro baños piso 1 | 4d | 2025-05-21 | 2025-05-26 | 587 | 185d |  | 2,629,224.81 |
| 599 | 6.4.2.4.2 | Enchape sobre muro baños piso 2 | 4d | 2025-06-04 | 2025-06-09 | 588 | 172d | 0d | 2,629,224.81 |
| 600 | 6.4.2.4.3 | Enchape sobre muro baños piso 3 | 4d | 2025-06-16 | 2025-06-20 | 589 | 161d | 0d | 2,629,224.81 |
| 601 | 6.4.2.4.4 | Enchape sobre muro baños piso 4 | 4d | 2025-07-01 | 2025-07-05 | 590 | 150d | 0d | 2,629,224.81 |
| 602 | 6.4.2.4.5 | Enchape sobre muro baños piso 5 | 4d | 2025-07-14 | 2025-07-17 | 591 | 139d | 0d | 2,629,224.81 |
| 603 | 6.4.2.4.6 | Enchape sobre muro baños piso 6 | 4d | 2025-07-25 | 2025-07-30 | 592 | 128d | 0d | 2,629,224.81 |
| 604 | 6.4.2.4.7 | Enchape sobre muro baños piso 7 | 4d | 2025-08-08 | 2025-08-13 | 593 | 117d | 0d | 2,629,224.81 |
| 605 | 6.4.2.4.8 | Enchape sobre muro baños piso 8 | 4d | 2025-08-21 | 2025-08-26 | 594 | 106d | 0d | 2,629,224.81 |
| 606 | 6.4.2.4.9 | Enchape sobre muro baños piso 9 | 4d | 2025-09-03 | 2025-09-08 | 595 | 95d | 0d | 2,629,224.81 |
| 607 | 6.4.2.4.10 | Enchape sobre muro baños piso 10 | 4d | 2025-09-16 | 2025-09-19 | 596 | 50d | 0d | 2,629,224.81 |

| ID | WBS | Task | Duration | Start | Finish | Predecessors | Total slack | Free slack | Cost |
| --- | --- | --- | --- | --- | --- | --- | --- | --- | --- |
| 608 | 6.4.2.5 | **Enchape sobre muro cocina** | 90d | 2025-06-09 | 2025-09-22 |  | 84d |  | 23,663,023.29 |
| 609 | 6.4.2.5.1 | Enchape sobre muro cocina piso 2 | 2d | 2025-06-09 | 2025-06-10 | 599 | 172d |  | 2,629,224.81 |
| 610 | 6.4.2.5.2 | Enchape sobre muro cocina piso 3 | 2d | 2025-06-20 | 2025-06-24 | 600 | 161d |  | 2,629,224.81 |
| 611 | 6.4.2.5.3 | Enchape sobre muro cocina piso 4 | 2d | 2025-07-05 | 2025-07-08 | 601 | 150d |  | 2,629,224.81 |
| 612 | 6.4.2.5.4 | Enchape sobre muro cocina piso 5 | 2d | 2025-07-17 | 2025-07-19 | 602 | 139d |  | 2,629,224.81 |
| 613 | 6.4.2.5.5 | Enchape sobre muro cocina piso 6 | 2d | 2025-07-30 | 2025-08-01 | 603 | 128d |  | 2,629,224.81 |
| 614 | 6.4.2.5.6 | Enchape sobre muro cocina piso 7 | 2d | 2025-08-13 | 2025-08-14 | 604 | 117d |  | 2,629,224.81 |
| 615 | 6.4.2.5.7 | Enchape sobre muro cocina piso 8 | 2d | 2025-08-26 | 2025-08-28 | 605 | 106d |  | 2,629,224.81 |
| 616 | 6.4.2.5.8 | Enchape sobre muro cocina piso 9 | 2d | 2025-09-08 | 2025-09-10 | 606 | 95d |  | 2,629,224.81 |
| 617 | 6.4.2.5.9 | Enchape sobre muro cocina piso 10 | 2d | 2025-09-19 | 2025-09-22 | 607 | 84d |  | 2,629,224.81 |
| 618 | 6.4.2.6 | **Enchape zonas comunes** | 44d | 2025-05-23 | 2025-07-15 |  | 143d |  | 13,344,220 |
| 619 | 6.4.2.6.1 | Enchape piso zonas comunes | 30d | 2025-05-23 | 2025-06-28 | 565 | 143d | 0d | 3,336,055 |
| 620 | 6.4.2.6.2 | Guardaescoba zonas comunes | 10d | 2025-06-28 | 2025-07-10 | 619 | 143d | 0d | 3,336,055 |
| 621 | 6.4.2.6.3 | Enchape piso shut de basuras | 2d | 2025-07-11 | 2025-07-14 | 620 | 143d | 0d | 3,336,055 |
| 622 | 6.4.2.6.4 | Enchape muro shut de basuras | 2d | 2025-07-14 | 2025-07-15 | 621 | 143d |  | 3,336,055 |
| 623 | 6.4.2.7 | **Enchape escaleras** | 98d | 2025-06-04 | 2025-09-26 |  | 80d |  | 3,873,200 |
| 624 | 6.4.2.7.1 | Enchape escalera Piso 1 | 3d | 2025-06-04 | 2025-06-06 | 328FS+28d | 175d |  | 387,320 |
| 625 | 6.4.2.7.2 | Enchape escalera Piso 2 | 3d | 2025-06-16 | 2025-06-19 | 329FS+28d | 164d |  | 387,320 |
| 626 | 6.4.2.7.3 | Enchape escalera Piso 3 | 3d | 2025-07-01 | 2025-07-04 | 330FS+28d | 153d |  | 387,320 |
| 627 | 6.4.2.7.4 | Enchape escalera Piso 4 | 3d | 2025-07-14 | 2025-07-16 | 331FS+28d | 142d |  | 387,320 |
| 628 | 6.4.2.7.5 | Enchape escalera Piso 5 | 3d | 2025-07-25 | 2025-07-29 | 332FS+28d | 131d |  | 387,320 |
| 629 | 6.4.2.7.6 | Enchape escalera Piso 6 | 3d | 2025-08-08 | 2025-08-12 | 333FS+28d | 120d |  | 387,320 |
| 630 | 6.4.2.7.7 | Enchape escalera Piso 7 | 3d | 2025-08-21 | 2025-08-25 | 334FS+28d | 109d |  | 387,320 |
| 631 | 6.4.2.7.8 | Enchape escalera Piso 8 | 3d | 2025-09-03 | 2025-09-06 | 335FS+28d | 98d |  | 387,320 |
| 632 | 6.4.2.7.9 | Enchape escalera Piso 9 | 3d | 2025-09-16 | 2025-09-18 | 336FS+28d | 87d |  | 387,320 |
| 633 | 6.4.2.7.10 | Enchape escalera Piso 10 | 3d | 2025-09-23 | 2025-09-26 | 337FS+28d | 80d |  | 387,320 |

| ID | WBS | Task | Duration | Start | Finish | Predecessors | Total slack | Free slack | Cost |
| --- | --- | --- | --- | --- | --- | --- | --- | --- | --- |
| 634 | 6.4.3 | **Pintura** | 115d | 2025-04-12 | 2025-08-29 |  | 105d |  | 23,001,344.66 |
| 635 | 6.4.3.1 | **Pintura interior primera mano** | 110d | 2025-04-12 | 2025-08-23 |  | 105d |  | 6,276,083.22 |
| 636 | 6.4.3.1.1 | Primera mano piso 1 | 4d | 2025-04-12 | 2025-04-19 | 299 | 211d | 0d | 570,553.02 |
| 637 | 6.4.3.1.2 | Primera mano piso 2 | 4d | 2025-04-28 | 2025-05-02 | 300 | 200d | 0d | 570,553.02 |
| 638 | 6.4.3.1.3 | Primera mano piso 3 | 4d | 2025-05-12 | 2025-05-15 | 301 | 189d | 0d | 570,553.02 |
| 639 | 6.4.3.1.4 | Primera mano piso 4 | 4d | 2025-05-23 | 2025-05-28 | 302 | 178d | 0d | 570,553.02 |
| 640 | 6.4.3.1.5 | Primera mano piso 5 | 4d | 2025-06-06 | 2025-06-10 | 303 | 167d | 0d | 570,553.02 |
| 641 | 6.4.3.1.6 | Primera mano piso 6 | 4d | 2025-06-18 | 2025-06-24 | 304 | 156d | 0d | 570,553.02 |
| 642 | 6.4.3.1.7 | Primera mano piso 7 | 4d | 2025-07-03 | 2025-07-08 | 305 | 145d | 0d | 570,553.02 |
| 643 | 6.4.3.1.8 | Primera mano piso 8 | 4d | 2025-07-16 | 2025-07-19 | 306 | 134d | 0d | 570,553.02 |
| 644 | 6.4.3.1.9 | Primera mano piso 9 | 4d | 2025-07-28 | 2025-08-01 | 307 | 123d | 0d | 570,553.02 |
| 645 | 6.4.3.1.10 | Primera mano piso 10 | 4d | 2025-08-11 | 2025-08-14 | 308 | 112d | 0d | 570,553.02 |
| 646 | 6.4.3.1.11 | Primera mano terraza | 4d | 2025-08-20 | 2025-08-23 | 309 | 0d |  | 570,553.02 |
| 647 | 6.4.3.2 | **Pintura interior segunda mano** | 109d | 2025-04-19 | 2025-08-27 |  | 105d |  | 6,276,083.22 |
| 648 | 6.4.3.2.1 | Segunda mano piso 1 | 3d | 2025-04-19 | 2025-04-23 | 636 | 211d | 0d | 570,553.02 |
| 649 | 6.4.3.2.2 | Segunda mano piso 2 | 3d | 2025-05-03 | 2025-05-07 | 637 | 200d | 0d | 570,553.02 |
| 650 | 6.4.3.2.3 | Segunda mano piso 3 | 3d | 2025-05-15 | 2025-05-19 | 638 | 189d | 0d | 570,553.02 |
| 651 | 6.4.3.2.4 | Segunda mano piso 4 | 3d | 2025-05-28 | 2025-05-30 | 639 | 178d | 0d | 570,553.02 |
| 652 | 6.4.3.2.5 | Segunda mano piso 5 | 3d | 2025-06-11 | 2025-06-13 | 640 | 167d | 0d | 570,553.02 |
| 653 | 6.4.3.2.6 | Segunda mano piso 6 | 3d | 2025-06-24 | 2025-06-27 | 641 | 156d | 0d | 570,553.02 |
| 654 | 6.4.3.2.7 | Segunda mano piso 7 | 3d | 2025-07-08 | 2025-07-10 | 642 | 145d | 0d | 570,553.02 |
| 655 | 6.4.3.2.8 | Segunda mano piso 8 | 3d | 2025-07-21 | 2025-07-23 | 643 | 134d | 0d | 570,553.02 |
| 656 | 6.4.3.2.9 | Segunda mano piso 9 | 3d | 2025-08-01 | 2025-08-05 | 644 | 123d | 0d | 570,553.02 |
| 657 | 6.4.3.2.10 | Segunda mano piso 10 | 3d | 2025-08-14 | 2025-08-19 | 645 | 112d | 0d | 570,553.02 |
| 658 | 6.4.3.2.11 | Segunda mano terraza | 3d | 2025-08-25 | 2025-08-27 | 646 | 0d |  | 570,553.02 |

| ID | WBS | Task | Duration | Start | Finish | Predecessors | Total slack | Free slack | Cost |
| --- | --- | --- | --- | --- | --- | --- | --- | --- | --- |
| 659 | 6.4.3.3 | **Pintura interior tercera mano** | 108d | 2025-04-23 | 2025-08-29 |  | 105d |  | 6,276,083.22 |
| 660 | 6.4.3.3.1 | Tercera mano piso 1 | 2d | 2025-04-23 | 2025-04-25 | 648 | 211d |  | 570,553.02 |
| 661 | 6.4.3.3.2 | Tercera mano piso 2 | 2d | 2025-05-07 | 2025-05-08 | 649 | 200d |  | 570,553.02 |
| 662 | 6.4.3.3.3 | Tercera mano piso 3 | 2d | 2025-05-19 | 2025-05-21 | 650 | 189d |  | 570,553.02 |
| 663 | 6.4.3.3.4 | Tercera mano piso 4 | 2d | 2025-05-31 | 2025-06-04 | 651 | 178d |  | 570,553.02 |
| 664 | 6.4.3.3.5 | Tercera mano piso 5 | 2d | 2025-06-13 | 2025-06-16 | 652 | 167d |  | 570,553.02 |
| 665 | 6.4.3.3.6 | Tercera mano piso 6 | 2d | 2025-06-27 | 2025-07-01 | 653 | 156d |  | 570,553.02 |
| 666 | 6.4.3.3.7 | Tercera mano piso 7 | 2d | 2025-07-11 | 2025-07-14 | 654 | 145d |  | 570,553.02 |
| 667 | 6.4.3.3.8 | Tercera mano piso 8 | 2d | 2025-07-23 | 2025-07-25 | 655 | 134d |  | 570,553.02 |
| 668 | 6.4.3.3.9 | Tercera mano piso 9 | 2d | 2025-08-05 | 2025-08-08 | 656 | 123d |  | 570,553.02 |
| 669 | 6.4.3.3.10 | Tercera mano piso 10 | 2d | 2025-08-20 | 2025-08-21 | 657 | 112d |  | 570,553.02 |
| 670 | 6.4.3.3.11 | Tercera mano terraza | 2d | 2025-08-27 | 2025-08-29 | 658 | 105d |  | 570,553.02 |
| 671 | 6.4.3.4 | **Pintura zonas comunes** | 15d | 2025-08-08 | 2025-08-26 |  | 108d |  | 4,173,095 |
| 672 | 6.4.3.4.1 | Pintura sobre pañete punto fijo | 7d | 2025-08-08 | 2025-08-15 | 295 | 108d | 0d | 130,815 |
| 673 | 6.4.3.4.2 | Pintura sobre pañete foso ascensor | 5d | 2025-08-15 | 2025-08-22 | 672 | 108d | 0d | 130,815 |
| 674 | 6.4.3.4.3 | Pintura sobre pañete cuarto de máquinas | 2d | 2025-08-22 | 2025-08-25 | 673 | 108d | 0d | 130,815 |
| 675 | 6.4.3.4.4 | Demarcación parqueaderos | 1d | 2025-08-25 | 2025-08-26 | 674 | 108d |  | 3,780,650 |
| 676 | 6.4.4 | **Fachada de ladrillo** | 17d | 2025-08-11 | 2025-08-30 |  | 104d |  | 24,000,000 |
| 677 | 6.4.4.1 | Limpieza de ladrillo de fachada | 15d | 2025-08-11 | 2025-08-28 | 283 | 104d | 0d | 12,000,000 |
| 678 | 6.4.4.2 | Impermeabilizacion ladrillo de fachada | 15d | 2025-08-13 | 2025-08-30 | 677SS+2d | 104d |  | 12,000,000 |
| 679 | 6.5 | **Carpinterias** | 95d | 2025-08-11 | 2025-11-29 |  | 14d |  | 357,813,273.72 |
| 680 | 6.5.1 | **Puertas** | 45d | 2025-08-27 | 2025-10-17 |  | 0d |  | 87,580,426 |
| 681 | 6.5.1.1 | **Puertas metálicas** | 45d | 2025-08-27 | 2025-10-17 |  | 62d |  | 22,620,426 |
| 682 | 6.5.1.1.1 | Puerta peatonal | 7d | 2025-08-27 | 2025-09-04 | 658 | 62d | 0d | 873,600 |
| 683 | 6.5.1.1.2 | Puerta vehicular | 14d | 2025-09-04 | 2025-09-19 | 682 | 62d | 0d | 3,000,000 |
| 684 | 6.5.1.1.3 | Puertas cortafuego | 7d | 2025-09-19 | 2025-09-27 | 683 | 62d | 0d | 14,458,500 |
| 685 | 6.5.1.1.4 | Puerta subestación | 7d | 2025-09-27 | 2025-10-06 | 684 | 62d | 0d | 2,098,726 |
| 686 | 6.5.1.1.5 | Puerta shut de basuras | 5d | 2025-10-06 | 2025-10-10 | 685 | 62d | 0d | 957,600 |
| 687 | 6.5.1.1.6 | Puerta de cuarto de bombas | 5d | 2025-10-10 | 2025-10-17 | 686 | 62d |  | 1,232,000 |

| ID | WBS | Task | Duration | Start | Finish | Predecessors | Total slack | Free slack | Cost |
| --- | --- | --- | --- | --- | --- | --- | --- | --- | --- |
| 688 | 6.5.1.2 | **Puertas de madera** | 42d | 2025-08-27 | 2025-10-15 |  | 0d |  | 64,960,000 |
| 689 | 6.5.1.2.1 | Instalación de puertas p1-P5 | 14d | 2025-08-27 | 2025-09-11 | 658 | 0d |  | 22,480,000 |
| 690 | 6.5.1.2.2 | Intalación chapas electricas p1-P5 | 7d | 2025-09-12 | 2025-09-19 | 689 | 0d |  | 10,000,000 |
| 691 | 6.5.1.2.3 | Instalación de puertas p6-P10 | 14d | 2025-09-19 | 2025-10-06 | 690 | 0d |  | 22,480,000 |
| 692 | 6.5.1.2.4 | Intalación chapas electricas p6-P10 | 7d | 2025-10-06 | 2025-10-15 | 691 | 0d |  | 10,000,000 |
| 693 | 6.5.2 | **Ventanas** | 88d | 2025-08-11 | 2025-11-21 |  | 33d |  | 109,110,560 |
| 694 | 6.5.2.1 | Ventana en aluminio | 20d | 2025-08-11 | 2025-09-03 | 283 | 101d |  | 70,000,000 |
| 695 | 6.5.2.2 | Puerta Ventana en aluminio | 25d | 2025-08-11 | 2025-09-09 | 283 | 37d | 0d | 30,000,000 |
| 696 | 6.5.2.3 | Rejillas de ventilación | 5d | 2025-09-19 | 2025-09-25 | 607 | 81d |  | 4,000,000 |
| 697 | 6.5.2.4 | Espejos baños | 5d | 2025-11-14 | 2025-11-21 | 722 | 33d |  | 5,110,560 |
| 698 | 6.5.3 | **Barandas** | 59d | 2025-09-09 | 2025-11-18 |  | 37d |  | 22,522,287.72 |
| 699 | 6.5.3.1 | Baranda balcón | 28d | 2025-09-09 | 2025-10-09 | 695 | 37d | 0d | 7,947,878 |
| 700 | 6.5.3.2 | Baranda punto fijo | 14d | 2025-10-10 | 2025-10-27 | 699 | 37d | 0d | 8,997,246.72 |
| 701 | 6.5.3.3 | Pasamanos punto fijo | 14d | 2025-10-27 | 2025-11-13 | 700 | 37d | 0d | 3,855,963 |
| 702 | 6.5.3.4 | Escalera de gato | 1d | 2025-11-13 | 2025-11-13 | 701 | 37d | 0d | 1,528,000 |
| 703 | 6.5.3.5 | Marcos y tapas sótano y cajas | 2d | 2025-11-14 | 2025-11-18 | 702 | 37d |  | 193,200 |
| 704 | 6.5.4 | **Muebles fijos** | 39d | 2025-10-15 | 2025-11-29 |  | 0d |  | 138,600,000 |
| 705 | 6.5.4.1 | Instalación de mueble de cocinas piso 2 | 2d | 2025-10-15 | 2025-10-16 | 692 | 0d |  | 5,600,000 |
| 706 | 6.5.4.2 | Instalación de mueble de cocinas piso 3 | 2d | 2025-10-16 | 2025-10-20 | 705 | 0d |  | 5,600,000 |
| 707 | 6.5.4.3 | Instalación de mueble de cocinas piso 4 | 2d | 2025-10-20 | 2025-10-21 | 706 | 0d |  | 5,600,000 |
| 708 | 6.5.4.4 | Instalación de mueble de cocinas piso 5 | 2d | 2025-10-21 | 2025-10-23 | 707 | 0d |  | 5,600,000 |
| 709 | 6.5.4.5 | Instalación de mueble de cocinas piso 6 | 2d | 2025-10-23 | 2025-10-25 | 708 | 0d |  | 5,600,000 |
| 710 | 6.5.4.6 | Instalación de mueble de cocinas piso 7 | 2d | 2025-10-25 | 2025-10-28 | 709 | 0d |  | 5,600,000 |
| 711 | 6.5.4.7 | Instalación de mueble de cocinas piso 8 | 2d | 2025-10-28 | 2025-10-30 | 710 | 0d |  | 5,600,000 |
| 712 | 6.5.4.8 | Instalación de mueble de cocinas piso 9 | 2d | 2025-10-30 | 2025-11-01 | 711 | 0d |  | 5,600,000 |
| 713 | 6.5.4.9 | Instalación de mueble de cocinas piso 10 | 2d | 2025-11-01 | 2025-11-05 | 712 | 0d |  | 5,600,000 |
| 714 | 6.5.4.10 | Instalación muebles de baño p2 | 1d | 2025-11-05 | 2025-11-06 | 713 | 0d |  | 1,400,000 |
| 715 | 6.5.4.11 | Instalación muebles de baño p3 | 1d | 2025-11-06 | 2025-11-07 | 714 | 0d |  | 1,400,000 |
| 716 | 6.5.4.12 | Instalación muebles de baño p4 | 1d | 2025-11-07 | 2025-11-08 | 715 | 0d |  | 1,400,000 |
| 717 | 6.5.4.13 | Instalación muebles de baño p5 | 1d | 2025-11-08 | 2025-11-10 | 716 | 0d |  | 1,400,000 |
| 718 | 6.5.4.14 | Instalación muebles de baño p6 | 1d | 2025-11-10 | 2025-11-11 | 717 | 0d |  | 1,400,000 |
| 719 | 6.5.4.15 | Instalación muebles de baño p7 | 1d | 2025-11-11 | 2025-11-12 | 718 | 0d |  | 1,400,000 |
| 720 | 6.5.4.16 | Instalación muebles de baño p8 | 1d | 2025-11-12 | 2025-11-13 | 719 | 0d |  | 1,400,000 |
| 721 | 6.5.4.17 | Instalación muebles de baño p9 | 1d | 2025-11-13 | 2025-11-13 | 720 | 0d |  | 1,400,000 |
| 722 | 6.5.4.18 | Instalación muebles de baño p10 | 1d | 2025-11-14 | 2025-11-14 | 721 | 0d |  | 1,400,000 |
| 723 | 6.5.4.19 | Instalación de CLOSET FUNCIONAL p2-P4 | 4d | 2025-11-14 | 2025-11-20 | 722 | 0d |  | 25,200,000 |
| 724 | 6.5.4.20 | Instalación de CLOSET FUNCIONAL p5-P7 | 4d | 2025-11-20 | 2025-11-25 | 723 | 0d |  | 25,200,000 |
| 725 | 6.5.4.21 | Instalación de CLOSET FUNCIONAL p8-P10 | 4d | 2025-11-25 | 2025-11-29 | 724 | 0d |  | 25,200,000 |

| ID | WBS | Task | Duration | Start | Finish | Predecessors | Total slack | Free slack | Cost |
| --- | --- | --- | --- | --- | --- | --- | --- | --- | --- |
| 726 | 6.6 | **Equipos** | 90d | 2025-08-15 | 2025-11-29 |  | 26d |  | 261,234,032 |
| 727 | 6.6.1 | **Equipos de cocina** | 7d | 2025-11-05 | 2025-11-13 |  | 40d |  | 67,400,244 |
| 728 | 6.6.1.1 | Estufa | 3d | 2025-11-05 | 2025-11-08 | 713 | 40d | 0d | 22,500,000 |
| 729 | 6.6.1.2 | Campana extractora | 3d | 2025-11-05 | 2025-11-08 | 728SS | 40d | 0d | 10,203,444 |
| 730 | 6.6.1.3 | Calentador | 4d | 2025-11-08 | 2025-11-13 | 729 | 40d |  | 34,696,800 |
| 731 | 6.6.2 | **Aparatos sanitarios** | 36d | 2025-09-19 | 2025-10-31 |  | 50d |  | 71,907,788 |
| 732 | 6.6.2.1 | Sanitario | 14d | 2025-09-19 | 2025-10-06 | 607 | 50d | 0d | 19,490,400 |
| 733 | 6.6.2.2 | Lavamanos | 14d | 2025-09-19 | 2025-10-06 | 732SS | 50d | 0d | 23,907,524 |
| 734 | 6.6.2.3 | Ducha | 10d | 2025-10-06 | 2025-10-17 | 733 | 50d | 0d | 18,000,000 |
| 735 | 6.6.2.4 | Juego de incrustaciones | 10d | 2025-10-06 | 2025-10-17 | 734SS | 50d | 0d | 9,457,344 |
| 736 | 6.6.2.5 | Taparegistro | 2d | 2025-10-17 | 2025-10-20 | 735 | 50d | 0d | 180,000 |
| 737 | 6.6.2.6 | Rejilla sifón de piso | 10d | 2025-10-21 | 2025-10-31 | 736 | 50d |  | 872,520 |
| 738 | 6.6.3 | **Equipos especiales** | 90d | 2025-08-15 | 2025-11-29 |  | 26d |  | 121,926,000 |
| 739 | 6.6.3.1 | Ascensor | 90d | 2025-08-15 | 2025-11-29 | 297 | 26d | 0d | 105,626,000 |
| 740 | 6.6.3.2 | Duplicadores | 30d | 2025-10-24 | 2025-11-29 | 739FF | 26d |  | 16,300,000 |
| 741 | 6.7 | **Obras exteriores** | 53d | 2025-08-11 | 2025-10-09 |  | 52d | 0d | 21,405,764 |
| 742 | 6.7.1 | **Actividades en andén** | 53d | 2025-08-11 | 2025-10-09 |  | 52d |  | 21,405,764 |
| 743 | 6.7.1.1 | Excavación anden | 7d | 2025-08-11 | 2025-08-19 | 283 | 52d | 0d | 5,718,003 |
| 744 | 6.7.1.2 | Cajas de Aguas Lluvias | 4d | 2025-08-20 | 2025-08-23 | 743 | 52d | 0d | 980,000 |
| 745 | 6.7.1.3 | Conexión red lluvias a calzada | 4d | 2025-08-25 | 2025-08-28 | 744 | 52d | 0d | 1,400,000 |
| 746 | 6.7.1.4 | Cajas de Aguas Negras | 4d | 2025-08-28 | 2025-09-02 | 745 | 52d | 0d | 1,050,000 |
| 747 | 6.7.1.5 | Conexiòn domicialiaria a colector | 4d | 2025-09-02 | 2025-09-06 | 746 | 52d | 0d | 1,050,000 |
| 748 | 6.7.1.6 | Caja de Agua Potable | 4d | 2025-09-06 | 2025-09-11 | 747 | 52d | 0d | 1,200,000 |
| 749 | 6.7.1.7 | Caja RITEL | 4d | 2025-09-11 | 2025-09-16 | 748 | 52d | 0d | 500,000 |
| 750 | 6.7.1.8 | Fundida de rampas y anden | 4d | 2025-09-16 | 2025-09-19 | 749 | 52d | 0d | 130,952 |
| 751 | 6.7.1.9 | Instalación de sardineles | 4d | 2025-09-19 | 2025-09-24 | 750 | 52d | 0d | 1,200,000 |
| 752 | 6.7.1.10 | Caja CS 276 -I | 2d | 2025-09-24 | 2025-09-26 | 751 | 52d | 0d | 1,050,000 |
| 753 | 6.7.1.11 | Excavaciòn pavimento e instalación tuberia PVC 6"Tramo 1 (FASE 1) | 2d | 2025-09-26 | 2025-09-29 | 752 | 52d | 0d | 800,000 |
| 754 | 6.7.1.12 | Reparación de pavimento (FASE I) | 2d | 2025-09-29 | 2025-10-01 | 753 | 52d | 0d | 150,000 |
| 755 | 6.7.1.13 | Excavaciòn pavimento e instalación tuberia PVC 6"Tramo 1 (FASE 2) | 2d | 2025-10-01 | 2025-10-03 | 754 | 52d | 0d | 1,320,000 |
| 756 | 6.7.1.14 | Reparación de pavimento (FASE II) | 2d | 2025-10-03 | 2025-10-06 | 755 | 52d | 0d | 756,809 |
| 757 | 6.7.1.15 | Caja CS 276 -II | 2d | 2025-10-06 | 2025-10-08 | 756 | 52d | 0d | 1,200,000 |
| 758 | 6.7.1.16 | Excavaciòn e instalación tuberia PVC 6" Tramo 2 | 2d | 2025-10-08 | 2025-10-09 | 757 | 52d |  | 2,900,000 |

| ID | WBS | Task | Type | Duration | Start | Finish | Predecessors | Total slack | Free slack | Cost |
| --- | --- | --- | --- | --- | --- | --- | --- | --- | --- | --- |
| 759 | 7 | **ACTIVIDADES FINALES Y DE CIERRE** |  | 26d | 2025-11-29 | 2025-12-31 |  | 0d |  | 80,188,975 |
| 760 | 7.1 | **Pruebas finales** |  | 20d | 2025-11-29 | 2025-12-23 |  | 6d |  | 20,000,000 |
| 761 | 7.1.1 | Prueba hidráulica |  | 5d | 2025-11-29 | 2025-12-05 | 725 | 6d | 0d | 5,000,000 |
| 762 | 7.1.2 | Prueba sanitaria |  | 5d | 2025-12-05 | 2025-12-12 | 761 | 6d | 0d | 5,000,000 |
| 763 | 7.1.3 | Prueba de red conta incendio |  | 5d | 2025-12-12 | 2025-12-18 | 762 | 6d | 0d | 5,000,000 |
| 764 | 7.1.4 | Prueba red de gas |  | 5d | 2025-12-18 | 2025-12-23 | 763 | 6d |  | 5,000,000 |
| 765 | 7.2 | **Certificaciones** |  | 22d | 2025-11-29 | 2025-12-26 |  | 0d |  | 36,000,000 |
| 766 | 7.2.1 | Certificación RETIE |  | 22d | 2025-11-29 | 2025-12-26 | 725 | 0d |  | 12,000,000 |
| 767 | 7.2.2 | Certificaciíon RITEL |  | 22d | 2025-11-29 | 2025-12-26 | 766SS | 4d | 0d | 12,000,000 |
| 768 | 7.2.3 | Certificación EDGE |  | 22d | 2025-11-29 | 2025-12-26 | 767SS | 4d |  | 12,000,000 |
| 769 | 7.3 | **Aseo** |  | 22d | 2025-12-04 | 2025-12-31 |  | 0d |  | 24,188,975 |
| 770 | 7.3.1 | Aseo fino para entrega apartamentos |  | 22d | 2025-12-04 | 2025-12-31 | 766SS+4d, 725 | 0d |  | 11,329,500 |
| 771 | 7.3.2 | Aseo fino para entrega zonas comunes |  | 15d | 2025-12-13 | 2025-12-31 | 770FF | 0d |  | 12,859,475 |
| 772 | 8 | FIN DEL PROYECTO | milestone | 0d | 2025-12-31 | 2025-12-31 | 771 | 0d |  |  |
